# Внедрение Exchange (полная версия)

Schedule from MS Project, 2010-05-10 to 2010-10-05, status date 2010-07-12, A marks actual dates.
rtl

## Calendars

- Стандартный: Mon-Fri 09:00-13:00, 14:00-18:00; Sat-Sun off.

## Resources

| Resource | Group |
| --- | --- |
| Заказчик проекта | Проектный офис |
| Руководитель проекта | ИТ |
| HR #0 | УК |
| HR #1 | В |
| HR #2 | А |
| Администратор Exchange | ИТ |
| Топ-менеджеры | Топ-менеджеры |
| Подрядчик по обучению | Outsourcing |
| HR #3 | Б |
| Закупщик ИТ | ИТ |

## Schedule

| ID | WBS | Task | Type | Duration | Start | Finish | Predecessors | Complete | Remaining | Baseline start | Baseline finish | Baseline duration | Total slack | Free slack | Constraint | Resources | Work | Actual work |
| --- | --- | --- | --- | --- | --- | --- | --- | --- | --- | --- | --- | --- | --- | --- | --- | --- | --- | --- |
| 1 | 1 | Начало проекта | milestone | 0d | 2010-05-10 A | 2010-05-10 A |  | 100% |  | 2010-05-10 | 2010-05-10 | 0d |  |  | start no earlier than 2010-05-10 |  |  |  |
| 2 | 2 | Проект завершен | milestone | 0d | 2010-10-05 | 2010-10-05 | 60, 81, 8, 16, 21, 46, 87, 31 |  |  | 2010-10-04 | 2010-10-04 | 0d | 0d |  |  |  |  |  |
| 3 | 3 | **Обученные пользователи** |  | 72d | 2010-05-10 A | 2010-08-17 |  | 51% | 35.58d | 2010-05-10 | 2010-08-24 | 77d | 35d |  |  |  | 1280h | 800h |
| 4 | 3.1 | **Подготовить тренеров** |  | 12d | 2010-05-10 A | 2010-05-25 A |  | 100% |  | 2010-05-10 | 2010-05-25 | 12d |  |  |  |  | 528h | 528h |
| 5 | 3.1.1 | Согласовать программу обучения тренеров с Заказчиком |  | 2d | 2010-05-10 A | 2010-05-11 A | 1 | 100% |  | 2010-05-10 | 2010-05-11 | 2d |  |  |  | Руководитель проекта; Заказчик проекта | 32h | 32h |
| 6 | 3.1.2 | Подписать договор на обучение тренеров |  | 2d | 2010-05-10 A | 2010-05-11 A | 1 | 100% |  | 2010-05-10 | 2010-05-11 | 2d |  |  |  | Руководитель проекта; Подрядчик по обучению | 16h | 16h |
| 7 | 3.1.3 | Пройти обучение для тренеров |  | 10d | 2010-05-12 A | 2010-05-25 A | 5, 6 | 100% |  | 2010-05-12 | 2010-05-25 | 10d |  |  |  | Подрядчик по обучению; HR #2; HR #1; Заказчик проекта; HR #0; HR #3 | 480h | 480h |
| 8 | 3.1.4 | Тренеры прошли обучение по работе с Системой | milestone | 0d | 2010-05-25 A | 2010-05-25 A | 7 | 100% |  | 2010-05-25 | 2010-05-25 | 0d |  |  |  |  |  |  |
| 9 | 3.2 | **Обучить топ-менеджеров** |  | 37d | 2010-05-19 A | 2010-07-08 A |  | 100% |  | 2010-05-19 | 2010-06-29 | 30d |  |  |  |  | 272h | 272h |
| 10 | 3.2.1 | Согласовать программу обучения топ-менеджеров с Заказчиком |  | 5d | 2010-05-19 A | 2010-05-25 A | 1 | 100% |  | 2010-05-19 | 2010-05-25 | 5d |  |  | as late as possible | Руководитель проекта; Заказчик проекта | 80h | 80h |
| 11 | 3.2.2 | Подготовить раздаточные материалы для обучения топ-менеджеров |  | 10d | 2010-05-26 A | 2010-06-08 A | 10, 8 | 100% |  | 2010-05-26 | 2010-06-08 | 10d |  |  |  | Руководитель проекта | 80h | 80h |
| 12 | 3.2.3 | Согласовать график проведения обучения с топ-менеджерами |  | 5d | 2010-05-26 A | 2010-06-01 A | 8 | 100% |  | 2010-05-26 | 2010-06-01 | 5d |  |  |  | Топ-менеджеры | 40h | 40h |
| 13 | 3.2.4 | Провести обучение топ-менеджеров (группа 1) |  | 3d | 2010-06-09 A | 2010-06-11 A | 12, 11 | 100% |  | 2010-06-09 | 2010-06-15 | 5d |  |  |  | HR #1 | 24h | 24h |
| 14 | 3.2.5 | Провести обучение топ-менеджеров (группа 2) |  | 5d | 2010-06-14 A | 2010-06-18 A | 13 | 100% |  | 2010-06-16 | 2010-06-22 | 5d |  |  |  | HR #2 | 40h | 40h |
| 15 | 3.2.6 | Провести обучение топ-менеджеров (группа 3) |  | 1d | 2010-07-08 A | 2010-07-08 A | 14 | 100% |  | 2010-06-23 | 2010-06-29 | 5d |  |  |  | HR #3 | 8h | 8h |
| 16 | 3.2.7 | Топ-менеджеры прошли обучение | milestone | 0d | 2010-07-08 A | 2010-07-08 A | 15 | 100% |  | 2010-06-29 | 2010-06-29 | 0d |  |  |  |  |  |  |
| 17 | 3.3 | **Обучить специалистов ИТ** |  | 12d | 2010-08-02 | 2010-08-17 |  |  |  | 2010-06-03 | 2010-06-18 | 12d | 35d |  |  |  | 224h |  |
| 18 | 3.3.1 | Согласовать программу обучения ИТ специалистов с Заказчиком |  | 2d | 2010-08-02 | 2010-08-03 | 1 |  |  | 2010-06-03 | 2010-06-04 | 2d | 35d | 0d | start no earlier than 2010-08-02 | Руководитель проекта; Заказчик проекта | 32h |  |
| 19 | 3.3.2 | Подписать договор на обучение ИТ специалистов |  | 2d | 2010-08-02 | 2010-08-03 | 1 |  |  |  |  |  | 35d | 0d | start no earlier than 2010-08-02 | Руководитель проекта; Подрядчик по обучению | 32h |  |
| 20 | 3.3.3 | Пройти обучение для ИТ-специалистов |  | 10d | 2010-08-04 | 2010-08-17 | 19, 18 |  |  | 2010-06-07 | 2010-06-18 | 10d | 35d | 0d |  | Подрядчик по обучению; Администратор Exchange | 160h |  |
| 21 | 3.3.4 | ИТ-специалисты прошли обучение | milestone | 0d | 2010-08-17 | 2010-08-17 | 20 |  |  | 2010-06-18 | 2010-06-18 | 0d | 35d |  |  |  |  |  |
| 22 | 3.4 | **Обучить менеджеров среднего звена** |  | 24d | 2010-07-09 | 2010-08-11 |  |  |  | 2010-06-30 | 2010-08-24 | 40d | 39d |  |  |  | 256h |  |
| 23 | 3.4.1 | Согласовать список менеджеров среднего звена к обучению с разбиением на группы |  | 4d | 2010-07-09 | 2010-07-14 | 16 |  |  | 2010-06-30 | 2010-07-06 | 5d | 39d | 0d |  | Руководитель проекта; Заказчик проекта | 64h |  |
| 24 | 3.4.2 | Согласовать график проведения обучения с менджерами среднего звена |  | 4d | 2010-07-09 | 2010-07-14 | 16 |  |  | 2010-06-30 | 2010-07-06 | 5d | 39d | 0d |  | Заказчик проекта | 32h |  |
| 25 | 3.4.3 | Провести обучение менеджеров среднего звена (группа 1) |  | 2d | 2010-07-15 | 2010-07-16 | 24, 23 |  |  | 2010-07-07 | 2010-07-13 | 5d | 39d | 0d | start no earlier than 2010-07-12 | HR #1 | 16h |  |
| 26 | 3.4.4 | Провести обучение менеджеров среднего звена (группа 2) |  | 4d | 2010-07-19 | 2010-07-22 | 25 |  |  | 2010-07-14 | 2010-07-20 | 5d | 39d | 0d |  | HR #2 | 32h |  |
| 27 | 3.4.5 | Провести обучение менеджеров среднего звена (группа 3) |  | 4d | 2010-07-23 | 2010-07-28 | 26 |  |  | 2010-07-21 | 2010-07-27 | 5d | 39d | 0d |  | HR #3 | 32h |  |
| 28 | 3.4.6 | Провести обучение менеджеров среднего звена (группа 4) |  | 3d | 2010-07-29 | 2010-08-02 | 27 |  |  | 2010-07-28 | 2010-08-03 | 5d | 39d | 0d |  | HR #1 | 24h |  |
| 29 | 3.4.7 | Провести обучение менеджеров среднего звена (группа 5) |  | 2d | 2010-08-03 | 2010-08-04 | 28 |  |  | 2010-08-04 | 2010-08-10 | 5d | 39d | 0d |  | HR #2 | 16h |  |
| 30 | 3.4.8 | Оценить результаты обучения менеджеров среднего звена |  | 5d | 2010-08-05 | 2010-08-11 | 29 |  |  | 2010-08-11 | 2010-08-24 | 10d | 39d | 0d |  | Заказчик проекта | 40h |  |
| 31 | 3.4.9 | Менеджеры среднего звена прошли обучение | milestone | 0d | 2010-08-11 | 2010-08-11 | 30 |  |  | 2010-08-24 | 2010-08-24 | 0d | 39d |  |  |  |  |  |

| ID | WBS | Task | Type | Duration | Start | Finish | Predecessors | Complete | Remaining | Baseline start | Baseline finish | Baseline duration | Total slack | Constraint | Resources | Work | Actual work |
| --- | --- | --- | --- | --- | --- | --- | --- | --- | --- | --- | --- | --- | --- | --- | --- | --- | --- |
| 32 | 4 | **Настроенная Система** |  | 21d | 2010-07-09 A | 2010-08-06 |  | 16% | 17.68d | 2010-06-16 | 2010-08-05 | 37d | 0d |  |  | 320h | 48h |
| 33 | 4.1 | **Подготовить требования к Системе** |  | 5d | 2010-07-09 A | 2010-07-15 A |  | 100% |  | 2010-06-16 | 2010-07-14 | 21d |  |  |  | 48h | 48h |
| 34 | 4.1.1 | Подготовить требования к настройке Системы. Направить на согласование |  | 2d | 2010-07-09 A | 2010-07-12 A | 16 | 100% |  | 2010-06-30 | 2010-07-06 | 5d |  |  | Руководитель проекта | 16h | 16h |
| 35 | 4.1.2 | Согласовать требования к настройке Системы. Высказать замечания |  | 3d | 2010-07-13 A | 2010-07-15 A | 34 | 100% |  | 2010-07-07 | 2010-07-08 | 2d |  |  | Заказчик проекта | 24h | 24h |
| 36 | 4.1.3 | Доработать требования к настройке Системы согласно замечаниям |  | 1d | 2010-07-14 A | 2010-07-15 A | 35 | 100% |  | 2010-07-09 | 2010-07-13 | 3d |  |  | Руководитель проекта | 8h | 8h |
| 37 | 4.1.4 | Подписать требования к настройке Системы | milestone | 0d | 2010-07-15 A | 2010-07-15 A | 36 | 100% |  | 2010-07-14 | 2010-07-14 | 0d |  |  | Заказчик проекта |  |  |
| 38 | 4.2 | **Настроить серверную часть** |  | 16d | 2010-07-16 | 2010-08-06 |  |  |  | 2010-07-15 | 2010-08-05 | 16d | 0d |  |  | 272h |  |
| 39 | 4.2.1 | Настроить серверную часть Календарь |  | 4d | 2010-07-16 | 2010-07-21 | 37 |  |  | 2010-07-15 | 2010-07-20 | 4d | 0d |  | Администратор Exchange | 32h |  |
| 40 | 4.2.2 | Настроить серверную часть Почта |  | 4d | 2010-07-22 | 2010-07-27 | 39 |  |  | 2010-07-21 | 2010-07-26 | 4d | 0d |  | Администратор Exchange | 32h |  |
| 41 | 4.2.3 | Настроить серверную часть Задачи |  | 4d | 2010-07-28 | 2010-08-02 | 40 |  |  | 2010-07-27 | 2010-07-30 | 4d | 0d |  | Администратор Exchange | 32h |  |
| 42 | 4.2.4 | Настроить серверную часть Контакты |  | 4d | 2010-08-03 | 2010-08-06 | 41 |  |  | 2010-08-02 | 2010-08-05 | 4d | 0d |  | Администратор Exchange | 32h |  |
| 43 | 4.2.5 | Настроить серверную часть Синхронизация и удаленный доступ |  | 10d | 2010-07-16 | 2010-07-29 | 37 |  |  | 2010-07-15 | 2010-07-28 | 10d | 0d |  | Администратор Exchange | 80h |  |
| 44 | 4.2.6 | Настроить серверную часть Технические настройки |  | 4d | 2010-07-30 | 2010-08-04 | 43 |  |  | 2010-07-29 | 2010-08-03 | 4d | 0d |  | Администратор Exchange | 32h |  |
| 45 | 4.2.7 | Проверить работоспособность настроенных функций |  | 2d | 2010-08-05 | 2010-08-06 | 44 |  |  | 2010-08-04 | 2010-08-05 | 2d | 0d |  | Руководитель проекта; Заказчик проекта | 32h |  |
| 46 | 4.2.8 | Серверная часть настроена в соответствии с требованиями | milestone | 0d | 2010-08-06 | 2010-08-06 | 45, 42 |  |  | 2010-08-05 | 2010-08-05 | 0d | 0d |  |  |  |  |
| 47 | 5 | **Документация к Системе** |  | 57d | 2010-07-19 | 2010-10-05 |  |  |  | 2010-07-16 | 2010-10-04 | 57d | 0d |  |  | 552h |  |
| 48 | 5.1 | Описать настройки Системы (адреса, пароли и явки) |  | 5d | 2010-08-09 | 2010-08-13 | 46 |  |  | 2010-08-06 | 2010-08-12 | 5d | 0d |  | Руководитель проекта | 40h |  |
| 49 | 5.2 | Предоставить формат описания пользовательской документации |  | 5d | 2010-07-19 | 2010-07-23 | 1 |  |  | 2010-07-16 | 2010-07-22 | 5d | 0d | as late as possible | Заказчик проекта | 40h |  |
| 50 | 5.3 | Разработать документацию к Системе. Календарь |  | 5d | 2010-07-26 | 2010-07-30 | 39, 49 |  |  | 2010-07-23 | 2010-07-29 | 5d | 0d |  | Руководитель проекта | 40h |  |
| 51 | 5.4 | Разработать документацию к Системе. Почта |  | 5d | 2010-08-02 | 2010-08-06 | 50, 40 |  |  | 2010-07-30 | 2010-08-05 | 5d | 0d |  | Руководитель проекта | 40h |  |
| 52 | 5.5 | Разработать документацию к Системе. Задачи |  | 5d | 2010-08-09 | 2010-08-13 | 51, 41 |  |  | 2010-08-06 | 2010-08-12 | 5d | 0d |  | Руководитель проекта | 40h |  |
| 53 | 5.6 | Разработать документацию к Системе. Контакты |  | 5d | 2010-08-16 | 2010-08-20 | 52, 42 |  |  | 2010-08-13 | 2010-08-19 | 5d | 0d |  | Руководитель проекта | 40h |  |
| 54 | 5.7 | Разработать документацию к Системе. Синхронизация и удаленный доступ |  | 5d | 2010-07-30 | 2010-08-05 | 43 |  |  | 2010-07-29 | 2010-08-04 | 5d | 11d |  | Руководитель проекта | 40h |  |
| 55 | 5.8 | Разработать документацию к Системе. Администрирование и поддержка Системы |  | 5d | 2010-08-16 | 2010-08-20 | 48, 44 |  |  | 2010-08-13 | 2010-08-19 | 5d | 0d |  | Руководитель проекта | 40h |  |
| 56 | 5.9 | Подписать Акт сдачи-приемки документации к Системе |  | 2d | 2010-08-23 | 2010-08-24 | 50, 51, 52, 53, 54, 55 |  |  | 2010-08-20 | 2010-08-23 | 2d | 0d |  | Руководитель проекта; Заказчик проекта | 32h |  |
| 57 | 5.10 | Резерв времени на разработку документации к Системе |  | 20d | 2010-08-25 | 2010-09-21 | 56 |  |  | 2010-08-24 | 2010-09-20 | 20d | 0d |  |  |  |  |
| 58 | 5.11 | Утвердить документацию к Системе на СД |  | 5d | 2010-09-22 | 2010-09-28 | 57 |  |  | 2010-09-21 | 2010-09-27 | 5d | 0d |  | Заказчик проекта | 40h |  |
| 59 | 5.12 | Ознакомить пользователей с документацией к Системе |  | 5d | 2010-09-29 | 2010-10-05 | 58 |  |  | 2010-09-28 | 2010-10-04 | 5d | 0d |  | HR #2; HR #3; HR #1; HR #0 | 160h |  |
| 60 | 5.13 | Заказчик принял документацию. Пользователи ознакомлены с документацией | milestone | 0d | 2010-10-05 | 2010-10-05 | 59 |  |  | 2010-10-04 | 2010-10-04 | 0d | 0d |  |  |  |  |

| ID | WBS | Task | Type | Duration | Start | Finish | Predecessors | Complete | Remaining | Baseline start | Baseline finish | Baseline duration | Total slack | Free slack | Constraint | Resources | Work | Actual work |
| --- | --- | --- | --- | --- | --- | --- | --- | --- | --- | --- | --- | --- | --- | --- | --- | --- | --- | --- |
| 61 | 6 | **Миграция пользователей и настройка клиентских мест** |  | 58d | 2010-07-16 | 2010-10-05 |  |  |  | 2010-07-15 | 2010-10-04 | 58d | 0d |  |  |  | 488h |  |
| 62 | 6.1 | Подготовить check-list выполнения миграции пользователей |  | 5d | 2010-07-16 | 2010-07-22 | 37 |  |  | 2010-07-15 | 2010-07-21 | 5d | 17d | 0d |  | Руководитель проекта | 40h |  |
| 63 | 6.2 | Проверить check-list. Высказать замечания |  | 2d | 2010-07-23 | 2010-07-26 | 62 |  |  | 2010-07-22 | 2010-07-23 | 2d | 17d | 0d |  | Заказчик проекта | 16h |  |
| 64 | 6.3 | Доработать check-list в соответствии с замечаниями |  | 2d | 2010-07-27 | 2010-07-28 | 63 |  |  | 2010-07-26 | 2010-07-27 | 2d | 17d | 7d |  | Руководитель проекта | 16h |  |
| 65 | 6.4 | Провести миграцию тестовой группы пользователей |  | 5d | 2010-08-09 | 2010-08-13 | 64, 46 |  |  | 2010-08-06 | 2010-08-12 | 5d | 10d | 0d |  | Администратор Exchange | 40h |  |
| 66 | 6.5 | Оценить результаты. Доработать check-list |  | 2d | 2010-08-16 | 2010-08-17 | 65 |  |  | 2010-08-13 | 2010-08-16 | 2d | 10d |  |  | Руководитель проекта | 16h |  |
| 67 | 6.6 | Разработать список пользователей к миграции с детализацией до компании |  | 5d | 2010-08-25 | 2010-08-31 | 1 |  |  | 2010-08-24 | 2010-08-30 | 5d | 0d |  | as late as possible | Руководитель проекта | 40h |  |
| 68 | 6.7 | Согласовать график проведения миграции с пользователями |  | 5d | 2010-09-01 | 2010-09-07 | 67, 66, 87 |  |  | 2010-08-31 | 2010-09-06 | 5d | 0d |  |  | Топ-менеджеры | 40h |  |
| 69 | 6.8 | Обеспечить миграцию топ-менеджеров, УК |  | 5d | 2010-09-08 | 2010-09-14 | 68 |  |  | 2010-09-07 | 2010-09-13 | 5d | 0d |  |  | Администратор Exchange | 40h |  |
| 70 | 6.9 | Подписать акт сдачи-приемки миграции топ-менеджеров и сотрудников УК | milestone | 0d | 2010-09-14 | 2010-09-14 | 69 |  |  | 2010-09-13 | 2010-09-13 | 0d | 0d |  |  | Руководитель проекта; Заказчик проекта |  |  |
| 71 | 6.10 | Обеспечить миграцию пользователей компании А |  | 5d | 2010-09-15 | 2010-09-21 | 70 |  |  | 2010-09-14 | 2010-09-20 | 5d | 0d |  |  | Администратор Exchange | 40h |  |
| 72 | 6.11 | Подписать акт сдачи-приемки миграции А | milestone | 0d | 2010-09-21 | 2010-09-21 | 71 |  |  | 2010-09-20 | 2010-09-20 | 0d | 0d |  |  | Руководитель проекта; Заказчик проекта |  |  |
| 73 | 6.12 | Обеспечить миграцию пользователей компании Б |  | 5d | 2010-09-22 | 2010-09-28 | 72 |  |  | 2010-09-21 | 2010-09-27 | 5d | 0d |  |  | Администратор Exchange | 40h |  |
| 74 | 6.13 | Подписать акт сдачи-приемки миграции Б | milestone | 0d | 2010-09-28 | 2010-09-28 | 73 |  |  | 2010-09-27 | 2010-09-27 | 0d | 0d |  |  | Руководитель проекта; Заказчик проекта |  |  |
| 75 | 6.14 | Обеспечить миграцию пользователей компании В |  | 5d | 2010-09-29 | 2010-10-05 | 74 |  |  | 2010-09-28 | 2010-10-04 | 5d | 0d |  |  | Администратор Exchange | 40h |  |
| 76 | 6.15 | Подписать акт сдачи-приемки миграции В | milestone | 0d | 2010-10-05 | 2010-10-05 | 75 |  |  | 2010-10-04 | 2010-10-04 | 0d | 0d |  |  | Руководитель проекта; Заказчик проекта |  |  |
| 77 | 6.16 | Обеспечить миграцию пользователей компании Г |  | 5d | 2010-09-08 | 2010-09-14 | 68 |  |  | 2010-09-07 | 2010-09-13 | 5d | 15d | 0d |  | Администратор Exchange | 40h |  |
| 78 | 6.17 | Подписать акт сдачи-приемки миграции Г | milestone | 0d | 2010-09-14 | 2010-09-14 | 77 |  |  | 2010-09-13 | 2010-09-13 | 0d | 15d |  |  | Руководитель проекта; Заказчик проекта |  |  |
| 79 | 6.18 | Обеспечить миграцию пользователей филиалов |  | 10d | 2010-09-08 | 2010-09-21 | 68 |  |  | 2010-09-07 | 2010-09-20 | 10d | 10d | 0d |  | Администратор Exchange | 80h |  |
| 80 | 6.19 | Подписать акт сдачи-приемки миграции филиалов | milestone | 0d | 2010-09-21 | 2010-09-21 | 79 |  |  | 2010-09-20 | 2010-09-20 | 0d | 10d |  |  | Руководитель проекта; Заказчик проекта |  |  |
| 81 | 6.20 | Миграция пользователей и настройка клиентских мест завершена | milestone | 0d | 2010-10-05 | 2010-10-05 | 80, 78, 76 |  |  | 2010-10-04 | 2010-10-04 | 0d | 0d |  |  |  |  |  |
| 82 | 7 | **Оборудование** |  | 59d | 2010-05-10 A | 2010-07-29 |  | 43% | 33.71d | 2010-05-10 | 2010-07-29 | 59d | 23d |  |  |  | 112h | 48h |
| 83 | 7.1 | Подать заявку на приобретение оборудования |  | 5d | 2010-05-10 A | 2010-05-14 A | 1 | 100% |  | 2010-05-10 | 2010-05-14 | 5d |  |  |  | Руководитель проекта | 40h | 40h |
| 84 | 7.2 | Закупить оборудование в соответствии с Заявкой |  | 1d | 2010-05-17 A | 2010-05-17 A | 83 | 100% |  | 2010-05-17 | 2010-05-17 | 1d |  |  |  | Закупщик ИТ | 8h | 8h |
| 85 | 7.3 | Установить оборудование |  | 3d | 2010-07-20 | 2010-07-22 | 84FS+45d |  |  | 2010-07-20 | 2010-07-22 | 3d | 23d | 0d |  | Руководитель проекта | 24h |  |
| 86 | 7.4 | Настроить и проверить работоспособность оборудование |  | 5d | 2010-07-23 | 2010-07-29 | 85 |  |  | 2010-07-23 | 2010-07-29 | 5d | 23d | 0d |  | Руководитель проекта | 40h |  |
| 87 | 7.5 | Оборудование приобретено, настроено и проверено | milestone | 0d | 2010-07-29 | 2010-07-29 | 86 |  |  | 2010-07-29 | 2010-07-29 | 0d | 23d |  |  |  |  |  |
