# Внедрение Exchange (структура, ресурсы и связи)

Schedule from MS Project, 2010-04-26 to 2010-09-03, status date 2010-07-12.
rtl

## Calendars

- Стандартный: Mon-Fri 09:00-13:00, 14:00-18:00; Sat-Sun off.

## Resources

| Resource | Group |
| --- | --- |
| Заказчик проекта | Проектный офис |
| Руководитель проекта | ИТ |
| HR #0 | УК |
| HR #1 | В |
| HR #2 | А |
| Администратор Exchange | ИТ |
| Топ-менеджеры | Топ-менеджеры |
| Подрядчик по обучению | Outsourcing |
| HR #3 | Б |
| Закупщик ИТ | ИТ |

## Schedule

| ID | WBS | Task | Type | Duration | Start | Finish | Predecessors | Total slack | Free slack | Constraint | Resources | Work |
| --- | --- | --- | --- | --- | --- | --- | --- | --- | --- | --- | --- | --- |
| 1 | 1 | Начало проекта | milestone | 0d | 2010-04-26 | 2010-04-26 |  | 0d |  |  |  |  |
| 2 | 2 | Проект завершен | milestone | 0d | 2010-09-03 | 2010-09-03 | 60, 81, 8, 16, 21, 46, 87, 31 | 0d |  |  |  |  |
| 3 | 3 | **Обученные пользователи** |  | 75d | 2010-04-26 | 2010-08-06 |  | 0d |  |  |  | 1280h |
| 4 | 3.1 | **Подготовить тренеров** |  | 12d | 2010-04-26 | 2010-05-11 |  | 0d |  |  |  | 528h |
| 5 | 3.1.1 | Согласовать программу обучения тренеров с Заказчиком |  | 2d | 2010-04-26 | 2010-04-27 | 1 | 0d |  |  | Руководитель проекта; Заказчик проекта | 32h |
| 6 | 3.1.2 | Подписать договор на обучение тренеров |  | 2d | 2010-04-26 | 2010-04-27 | 1 | 0d |  |  | Руководитель проекта; Подрядчик по обучению | 16h |
| 7 | 3.1.3 | Пройти обучение для тренеров |  | 10d | 2010-04-28 | 2010-05-11 | 5, 6 | 0d |  |  | Подрядчик по обучению; HR #2; HR #1; Заказчик проекта; HR #0; HR #3 | 480h |
| 8 | 3.1.4 | Тренеры прошли обучение по работе с Системой | milestone | 0d | 2010-05-11 | 2010-05-11 | 7 | 0d |  |  |  |  |
| 9 | 3.2 | **Обучить топ-менеджеров** |  | 31d | 2010-04-26 | 2010-06-07 |  | 0d |  |  |  | 272h |
| 10 | 3.2.1 | Согласовать программу обучения топ-менеджеров с Заказчиком |  | 5d | 2010-04-26 | 2010-04-30 | 1 | 7d |  |  | Руководитель проекта; Заказчик проекта | 80h |
| 11 | 3.2.2 | Подготовить раздаточные материалы для обучения топ-менеджеров |  | 10d | 2010-05-12 | 2010-05-25 | 10, 8 | 0d |  |  | Руководитель проекта | 80h |
| 12 | 3.2.3 | Согласовать график проведения обучения с топ-менеджерами |  | 5d | 2010-05-12 | 2010-05-18 | 8 | 5d |  |  | Топ-менеджеры | 40h |
| 13 | 3.2.4 | Провести обучение топ-менеджеров (группа 1) |  | 3d | 2010-05-26 | 2010-05-28 | 12, 11 | 0d |  |  | HR #1 | 24h |
| 14 | 3.2.5 | Провести обучение топ-менеджеров (группа 2) |  | 5d | 2010-05-31 | 2010-06-04 | 13 | 0d |  |  | HR #2 | 40h |
| 15 | 3.2.6 | Провести обучение топ-менеджеров (группа 3) |  | 1d | 2010-06-07 | 2010-06-07 | 14 | 0d |  |  | HR #3 | 8h |
| 16 | 3.2.7 | Топ-менеджеры прошли обучение | milestone | 0d | 2010-06-07 | 2010-06-07 | 15 | 0d |  |  |  |  |
| 17 | 3.3 | **Обучить специалистов ИТ** |  | 12d | 2010-04-26 | 2010-05-11 |  | 83d |  |  |  | 224h |
| 18 | 3.3.1 | Согласовать программу обучения ИТ специалистов с Заказчиком |  | 2d | 2010-04-26 | 2010-04-27 | 1 | 83d | 0d |  | Руководитель проекта; Заказчик проекта | 32h |
| 19 | 3.3.2 | Подписать договор на обучение ИТ специалистов |  | 2d | 2010-04-26 | 2010-04-27 | 1 | 83d | 0d |  | Руководитель проекта; Подрядчик по обучению | 32h |
| 20 | 3.3.3 | Пройти обучение для ИТ-специалистов |  | 10d | 2010-04-28 | 2010-05-11 | 19, 18 | 83d | 0d |  | Подрядчик по обучению; Администратор Exchange | 160h |
| 21 | 3.3.4 | ИТ-специалисты прошли обучение | milestone | 0d | 2010-05-11 | 2010-05-11 | 20 | 83d |  |  |  |  |
| 22 | 3.4 | **Обучить менеджеров среднего звена** |  | 44d | 2010-06-08 | 2010-08-06 |  | 20d |  |  |  | 256h |
| 23 | 3.4.1 | Согласовать список менеджеров среднего звена к обучению с разбиением на группы |  | 4d | 2010-06-08 | 2010-06-11 | 16 | 40d | 20d |  | Руководитель проекта; Заказчик проекта | 64h |
| 24 | 3.4.2 | Согласовать график проведения обучения с менджерами среднего звена |  | 4d | 2010-06-08 | 2010-06-11 | 16 | 40d | 20d |  | Заказчик проекта | 32h |
| 25 | 3.4.3 | Провести обучение менеджеров среднего звена (группа 1) |  | 2d | 2010-07-12 | 2010-07-13 | 24, 23 | 20d | 0d | start no earlier than 2010-07-12 | HR #1 | 16h |
| 26 | 3.4.4 | Провести обучение менеджеров среднего звена (группа 2) |  | 4d | 2010-07-14 | 2010-07-19 | 25 | 20d | 0d |  | HR #2 | 32h |
| 27 | 3.4.5 | Провести обучение менеджеров среднего звена (группа 3) |  | 4d | 2010-07-20 | 2010-07-23 | 26 | 20d | 0d |  | HR #3 | 32h |
| 28 | 3.4.6 | Провести обучение менеджеров среднего звена (группа 4) |  | 3d | 2010-07-26 | 2010-07-28 | 27 | 20d | 0d |  | HR #1 | 24h |
| 29 | 3.4.7 | Провести обучение менеджеров среднего звена (группа 5) |  | 2d | 2010-07-29 | 2010-07-30 | 28 | 20d | 0d |  | HR #2 | 16h |
| 30 | 3.4.8 | Оценить результаты обучения менеджеров среднего звена |  | 5d | 2010-08-02 | 2010-08-06 | 29 | 20d | 0d |  | Заказчик проекта | 40h |
| 31 | 3.4.9 | Менеджеры среднего звена прошли обучение | milestone | 0d | 2010-08-06 | 2010-08-06 | 30 | 20d |  |  |  |  |

| ID | WBS | Task | Type | Duration | Start | Finish | Predecessors | Total slack | Constraint | Resources | Work |
| --- | --- | --- | --- | --- | --- | --- | --- | --- | --- | --- | --- |
| 32 | 4 | **Настроенная Система** |  | 22d | 2010-06-08 | 2010-07-07 |  | 0d |  |  | 320h |
| 33 | 4.1 | **Подготовить требования к Системе** |  | 6d | 2010-06-08 | 2010-06-15 |  | 0d |  |  | 48h |
| 34 | 4.1.1 | Подготовить требования к настройке Системы. Направить на согласование |  | 2d | 2010-06-08 | 2010-06-09 | 16 | 0d |  | Руководитель проекта | 16h |
| 35 | 4.1.2 | Согласовать требования к настройке Системы. Высказать замечания |  | 3d | 2010-06-10 | 2010-06-14 | 34 | 0d |  | Заказчик проекта | 24h |
| 36 | 4.1.3 | Доработать требования к настройке Системы согласно замечаниям |  | 1d | 2010-06-15 | 2010-06-15 | 35 | 0d |  | Руководитель проекта | 8h |
| 37 | 4.1.4 | Подписать требования к настройке Системы | milestone | 0d | 2010-06-15 | 2010-06-15 | 36 | 0d |  | Заказчик проекта |  |
| 38 | 4.2 | **Настроить серверную часть** |  | 16d | 2010-06-16 | 2010-07-07 |  | 0d |  |  | 272h |
| 39 | 4.2.1 | Настроить серверную часть Календарь |  | 4d | 2010-06-16 | 2010-06-21 | 37 | 0d |  | Администратор Exchange | 32h |
| 40 | 4.2.2 | Настроить серверную часть Почта |  | 4d | 2010-06-22 | 2010-06-25 | 39 | 0d |  | Администратор Exchange | 32h |
| 41 | 4.2.3 | Настроить серверную часть Задачи |  | 4d | 2010-06-28 | 2010-07-01 | 40 | 0d |  | Администратор Exchange | 32h |
| 42 | 4.2.4 | Настроить серверную часть Контакты |  | 4d | 2010-07-02 | 2010-07-07 | 41 | 0d |  | Администратор Exchange | 32h |
| 43 | 4.2.5 | Настроить серверную часть Синхронизация и удаленный доступ |  | 10d | 2010-06-16 | 2010-06-29 | 37 | 0d |  | Администратор Exchange | 80h |
| 44 | 4.2.6 | Настроить серверную часть Технические настройки |  | 4d | 2010-06-30 | 2010-07-05 | 43 | 0d |  | Администратор Exchange | 32h |
| 45 | 4.2.7 | Проверить работоспособность настроенных функций |  | 2d | 2010-07-06 | 2010-07-07 | 44 | 0d |  | Руководитель проекта; Заказчик проекта | 32h |
| 46 | 4.2.8 | Серверная часть настроена в соответствии с требованиями | milestone | 0d | 2010-07-07 | 2010-07-07 | 45, 42 | 0d |  |  |  |
| 47 | 5 | **Документация к Системе** |  | 57d | 2010-06-17 | 2010-09-03 |  | 0d |  |  | 552h |
| 48 | 5.1 | Описать настройки Системы (адреса, пароли и явки) |  | 5d | 2010-07-08 | 2010-07-14 | 46 | 0d |  | Руководитель проекта | 40h |
| 49 | 5.2 | Предоставить формат описания пользовательской документации |  | 5d | 2010-06-17 | 2010-06-23 | 1 | 0d | as late as possible | Заказчик проекта | 40h |
| 50 | 5.3 | Разработать документацию к Системе. Календарь |  | 5d | 2010-06-24 | 2010-06-30 | 39, 49 | 0d |  | Руководитель проекта | 40h |
| 51 | 5.4 | Разработать документацию к Системе. Почта |  | 5d | 2010-07-01 | 2010-07-07 | 50, 40 | 0d |  | Руководитель проекта | 40h |
| 52 | 5.5 | Разработать документацию к Системе. Задачи |  | 5d | 2010-07-08 | 2010-07-14 | 51, 41 | 0d |  | Руководитель проекта | 40h |
| 53 | 5.6 | Разработать документацию к Системе. Контакты |  | 5d | 2010-07-15 | 2010-07-21 | 52, 42 | 0d |  | Руководитель проекта | 40h |
| 54 | 5.7 | Разработать документацию к Системе. Синхронизация и удаленный доступ |  | 5d | 2010-06-30 | 2010-07-06 | 43 | 11d |  | Руководитель проекта | 40h |
| 55 | 5.8 | Разработать документацию к Системе. Администрирование и поддержка Системы |  | 5d | 2010-07-15 | 2010-07-21 | 48, 44 | 0d |  | Руководитель проекта | 40h |
| 56 | 5.9 | Подписать Акт сдачи-приемки документации к Системе |  | 2d | 2010-07-22 | 2010-07-23 | 50, 51, 52, 53, 54, 55 | 0d |  | Руководитель проекта; Заказчик проекта | 32h |
| 57 | 5.10 | Резерв времени на разработку документации к Системе |  | 20d | 2010-07-26 | 2010-08-20 | 56 | 0d |  |  |  |
| 58 | 5.11 | Утвердить документацию к Системе на СД |  | 5d | 2010-08-23 | 2010-08-27 | 57 | 0d |  | Заказчик проекта | 40h |
| 59 | 5.12 | Ознакомить пользователей с документацией к Системе |  | 5d | 2010-08-30 | 2010-09-03 | 58 | 0d |  | HR #2; HR #3; HR #1; HR #0 | 160h |
| 60 | 5.13 | Заказчик принял документацию. Пользователи ознакомлены с документацией | milestone | 0d | 2010-09-03 | 2010-09-03 | 59 | 0d |  |  |  |

| ID | WBS | Task | Type | Duration | Start | Finish | Predecessors | Total slack | Free slack | Constraint | Resources | Work |
| --- | --- | --- | --- | --- | --- | --- | --- | --- | --- | --- | --- | --- |
| 61 | 6 | **Миграция пользователей и настройка клиентских мест** |  | 58d | 2010-06-16 | 2010-09-03 |  | 0d |  |  |  | 488h |
| 62 | 6.1 | Подготовить check-list выполнения миграции пользователей |  | 5d | 2010-06-16 | 2010-06-22 | 37 | 17d | 0d |  | Руководитель проекта | 40h |
| 63 | 6.2 | Проверить check-list. Высказать замечания |  | 2d | 2010-06-23 | 2010-06-24 | 62 | 17d | 0d |  | Заказчик проекта | 16h |
| 64 | 6.3 | Доработать check-list в соответствии с замечаниями |  | 2d | 2010-06-25 | 2010-06-28 | 63 | 17d | 7d |  | Руководитель проекта | 16h |
| 65 | 6.4 | Провести миграцию тестовой группы пользователей |  | 5d | 2010-07-08 | 2010-07-14 | 64, 46 | 10d | 0d |  | Администратор Exchange | 40h |
| 66 | 6.5 | Оценить результаты. Доработать check-list |  | 2d | 2010-07-15 | 2010-07-16 | 65 | 10d |  |  | Руководитель проекта | 16h |
| 67 | 6.6 | Разработать список пользователей к миграции с детализацией до компании |  | 5d | 2010-07-26 | 2010-07-30 | 1 | 0d |  | as late as possible | Руководитель проекта | 40h |
| 68 | 6.7 | Согласовать график проведения миграции с пользователями |  | 5d | 2010-08-02 | 2010-08-06 | 67, 66, 87 | 0d |  |  | Топ-менеджеры | 40h |
| 69 | 6.8 | Обеспечить миграцию топ-менеджеров, УК |  | 5d | 2010-08-09 | 2010-08-13 | 68 | 0d |  |  | Администратор Exchange | 40h |
| 70 | 6.9 | Подписать акт сдачи-приемки миграции топ-менеджеров и сотрудников УК | milestone | 0d | 2010-08-13 | 2010-08-13 | 69 | 0d |  |  | Руководитель проекта; Заказчик проекта |  |
| 71 | 6.10 | Обеспечить миграцию пользователей компании А |  | 5d | 2010-08-16 | 2010-08-20 | 70 | 0d |  |  | Администратор Exchange | 40h |
| 72 | 6.11 | Подписать акт сдачи-приемки миграции А | milestone | 0d | 2010-08-20 | 2010-08-20 | 71 | 0d |  |  | Руководитель проекта; Заказчик проекта |  |
| 73 | 6.12 | Обеспечить миграцию пользователей компании Б |  | 5d | 2010-08-23 | 2010-08-27 | 72 | 0d |  |  | Администратор Exchange | 40h |
| 74 | 6.13 | Подписать акт сдачи-приемки миграции Б | milestone | 0d | 2010-08-27 | 2010-08-27 | 73 | 0d |  |  | Руководитель проекта; Заказчик проекта |  |
| 75 | 6.14 | Обеспечить миграцию пользователей компании В |  | 5d | 2010-08-30 | 2010-09-03 | 74 | 0d |  |  | Администратор Exchange | 40h |
| 76 | 6.15 | Подписать акт сдачи-приемки миграции В | milestone | 0d | 2010-09-03 | 2010-09-03 | 75 | 0d |  |  | Руководитель проекта; Заказчик проекта |  |
| 77 | 6.16 | Обеспечить миграцию пользователей компании Г |  | 5d | 2010-08-09 | 2010-08-13 | 68 | 15d | 0d |  | Администратор Exchange | 40h |
| 78 | 6.17 | Подписать акт сдачи-приемки миграции Г | milestone | 0d | 2010-08-13 | 2010-08-13 | 77 | 15d |  |  | Руководитель проекта; Заказчик проекта |  |
| 79 | 6.18 | Обеспечить миграцию пользователей филиалов |  | 10d | 2010-08-09 | 2010-08-20 | 68 | 10d | 0d |  | Администратор Exchange | 80h |
| 80 | 6.19 | Подписать акт сдачи-приемки миграции филиалов | milestone | 0d | 2010-08-20 | 2010-08-20 | 79 | 10d |  |  | Руководитель проекта; Заказчик проекта |  |
| 81 | 6.20 | Миграция пользователей и настройка клиентских мест завершена | milestone | 0d | 2010-09-03 | 2010-09-03 | 80, 78, 76 | 0d |  |  |  |  |
| 82 | 7 | **Оборудование** |  | 14d | 2010-04-26 | 2010-05-13 |  | 56d |  |  |  | 112h |
| 83 | 7.1 | Подать заявку на приобретение оборудования |  | 5d | 2010-04-26 | 2010-04-30 | 1 | 56d | 0d |  | Руководитель проекта | 40h |
| 84 | 7.2 | Закупить оборудование в соответствии с Заявкой |  | 1d | 2010-05-03 | 2010-05-03 | 83 | 56d | 0d |  | Закупщик ИТ | 8h |
| 85 | 7.3 | Установить оборудование |  | 3d | 2010-05-04 | 2010-05-06 | 84 | 56d | 0d |  | Руководитель проекта | 24h |
| 86 | 7.4 | Настроить и проверить работоспособность оборудование |  | 5d | 2010-05-07 | 2010-05-13 | 85 | 56d | 0d |  | Руководитель проекта | 40h |
| 87 | 7.5 | Оборудование приобретено, настроено и проверено | milestone | 0d | 2010-05-13 | 2010-05-13 | 86 | 56d |  |  |  |  |
