# Проект "Ребрендинг"

Schedule from MS Project, 2010-01-21 to 2010-08-26, status date 2010-07-30, A marks actual dates.
Microsoft

## Calendars

- Стандартный: Mon-Fri 09:00-13:00, 14:00-18:00; Sat-Sun off.

## Resources

| Resource | Group |
| --- | --- |
| Заказчик | Компания АБВ |
| Руководитель проекта | Управляющая компания |
| Подрядчик ФС | Подрядчик |
| Подрядчик Сайт | Подрядчик |
| Совет Директоров | Управляющая компания |
| Специалист ИТ | ИТ |
| Юрист | Компания АБВ |

## Schedule

| ID | WBS | Task | Type | Duration | Start | Finish | Predecessors | Complete | Remaining | Baseline start | Baseline finish | Baseline duration | Baseline 1 start | Baseline 1 finish | Total slack | Constraint | Resources | Work | Actual work |
| --- | --- | --- | --- | --- | --- | --- | --- | --- | --- | --- | --- | --- | --- | --- | --- | --- | --- | --- | --- |
| 1 | 1 | **Разработать описание целевой аудитории** |  | 10d | 2010-01-21 A | 2010-02-03 A |  | 100% |  | 2010-01-21 | 2010-02-03 | 10d | 2010-01-21 | 2010-02-03 |  |  |  | 32h | 32h |
| 2 | 1.1 | Разработать описание целевой аудитории |  | 2d | 2010-01-21 A | 2010-01-22 A | 109 | 100% |  | 2010-01-21 | 2010-01-22 | 2d | 2010-01-21 | 2010-01-22 |  |  | Руководитель проекта | 16h | 16h |
| 3 | 1.2 | Согласовать описание целевой аудитории |  | 2d | 2010-02-02 A | 2010-02-03 A | 2 | 100% |  | 2010-01-25 | 2010-01-29 | 5d | 2010-01-25 | 2010-01-29 |  | start no earlier than 2010-02-01 | Заказчик | 16h | 16h |
| 4 | 1.3 | Доработать описание целевой аудитории | milestone | 0d | 2010-02-03 A | 2010-02-03 A | 3 | 100% |  | 2010-02-01 | 2010-02-02 | 2d | 2010-02-01 | 2010-02-02 |  |  | Руководитель проекта |  |  |
| 5 | 1.4 | Утвердить описания целевой аудитории | milestone | 0d | 2010-02-03 A | 2010-02-03 A | 4 | 100% |  | 2010-02-03 | 2010-02-03 | 1d | 2010-02-03 | 2010-02-03 |  |  | Заказчик |  |  |
| 6 | 1.5 | Описание целевой аудитории утверждено Заказчиком | milestone | 0d | 2010-02-03 A | 2010-02-03 A | 5 | 100% |  | 2010-02-03 | 2010-02-03 | 0d | 2010-02-03 | 2010-02-03 |  |  |  |  |  |
| 7 | 2 | **Разработать фирменный стиль логистического провайдера** |  | 52d | 2010-02-16 A | 2010-04-28 A |  | 100% |  | 2010-02-04 | 2010-04-15 | 51d | 2010-02-04 | 2010-04-15 |  |  |  | 664h | 664h |
| 8 | 2.1 | Разработать требования к фирменному стилю |  | 6d | 2010-02-16 A | 2010-02-23 A | 6 | 100% |  | 2010-02-04 | 2010-02-05 | 2d | 2010-02-04 | 2010-02-05 |  | start no earlier than 2010-02-15 | Руководитель проекта | 48h | 48h |
| 9 | 2.2 | Согласовать требования к фирменному стилю |  | 2d | 2010-02-24 A | 2010-02-25 A | 8 | 100% |  | 2010-02-08 | 2010-02-12 | 5d | 2010-02-08 | 2010-02-12 |  |  | Заказчик; Совет Директоров | 16h | 16h |
| 10 | 2.3 | Доработать требования к фирменному стилю по результатам согласования | milestone | 0d | 2010-02-25 A | 2010-02-25 A | 9 | 100% |  | 2010-02-15 | 2010-02-16 | 2d | 2010-02-15 | 2010-02-16 |  |  | Руководитель проекта |  |  |
| 11 | 2.4 | Утвердить требования к фирменному стилю | milestone | 0d | 2010-02-25 A | 2010-02-25 A | 10 | 100% |  | 2010-02-17 | 2010-02-17 | 1d | 2010-02-17 | 2010-02-17 |  |  | Руководитель проекта; Заказчик |  |  |
| 12 | 2.5 | Резерв к вехе "Требования к фирменному стилю утверждены" | milestone | 0d | 2010-02-25 A | 2010-02-25 A | 11 | 100% |  | 2010-02-18 | 2010-02-24 | 5d | 2010-02-18 | 2010-02-24 |  |  |  |  |  |
| 13 | 2.6 | Требования к фирменному стилю утверждены Заказчиком | milestone | 0d | 2010-02-25 A | 2010-02-25 A | 12 | 100% |  | 2010-02-24 | 2010-02-24 | 0d | 2010-02-24 | 2010-02-24 |  |  |  |  |  |
| 14 | 2.7 | **Разработать фирменный стиль** |  | 44d | 2010-02-26 A | 2010-04-28 A |  | 100% |  | 2010-02-25 | 2010-04-15 | 36d | 2010-02-25 | 2010-04-15 |  |  |  | 600h | 600h |
| 15 | 2.7.1 | Совещание 1 |  | 5d | 2010-02-26 A | 2010-03-04 A | 13 | 100% |  | 2010-02-25 | 2010-03-03 | 5d | 2010-02-25 | 2010-03-03 |  |  | Руководитель проекта; Заказчик; Подрядчик ФС | 120h | 120h |
| 16 | 2.7.2 | Совещание с подрядчиком 2 |  | 5d | 2010-03-05 A | 2010-03-11 A | 15 | 100% |  | 2010-03-04 | 2010-03-10 | 5d | 2010-03-04 | 2010-03-10 |  |  | Руководитель проекта; Заказчик; Подрядчик ФС | 120h | 120h |
| 17 | 2.7.3 | Совещание с подрядчиком 3 |  | 8d | 2010-03-29 A | 2010-04-07 A | 16 | 100% |  | 2010-03-11 | 2010-03-17 | 5d | 2010-03-11 | 2010-03-17 |  | start no earlier than 2010-03-29 | Руководитель проекта; Заказчик; Подрядчик ФС | 192h | 192h |
| 18 | 2.7.4 | Доработать фирменный стиль |  | 15d | 2010-04-08 A | 2010-04-28 A | 17 | 100% |  | 2010-03-18 | 2010-03-24 | 5d | 2010-03-18 | 2010-03-24 |  |  | Подрядчик ФС | 120h | 120h |
| 19 | 2.7.5 | Утвердить фирменный стиль |  | 6d | 2010-04-21 A | 2010-04-28 A | 18 | 100% |  | 2010-03-25 | 2010-03-25 | 1d | 2010-03-25 | 2010-03-25 |  |  | Совет Директоров | 48h | 48h |
| 20 | 2.7.6 | Резерв к вехе "Фирменный стиль утвержден" | milestone | 0d | 2010-04-28 A | 2010-04-28 A | 19 | 100% |  | 2010-03-26 | 2010-04-15 | 15d | 2010-03-26 | 2010-04-15 |  |  |  |  |  |
| 21 | 2.7.7 | Фирменный стиль утвержден Советом директоров УК | milestone | 0d | 2010-04-28 A | 2010-04-28 A | 20 | 100% |  | 2010-04-15 | 2010-04-15 | 0d | 2010-04-15 | 2010-04-15 |  |  |  |  |  |
| 22 | 3 | **Разработать web-сайт логистического провайдера** |  | 113d | 2010-03-22 A | 2010-08-25 |  | 81% | 21.02d | 2010-02-25 | 2010-07-07 | 95d | 2010-02-25 | 2010-07-07 | 1d |  |  | 1272h | 968h |
| 23 | 3.1 | **Разработать концепцию сайта** |  | 13d | 2010-03-22 A | 2010-04-07 A |  | 100% |  | 2010-02-25 | 2010-03-10 | 10d | 2010-02-25 | 2010-03-10 |  |  |  | 120h | 120h |
| 24 | 3.1.1 | Разработать концепцию сайта |  | 9d | 2010-03-22 A | 2010-04-01 A | 13 | 100% |  | 2010-02-25 | 2010-02-26 | 2d | 2010-02-25 | 2010-02-26 |  | start no earlier than 2010-03-22 | Руководитель проекта | 72h | 72h |
| 25 | 3.1.2 | Согласовать концепцию сайта |  | 2d | 2010-04-02 A | 2010-04-05 A | 24 | 100% |  | 2010-03-01 | 2010-03-05 | 5d | 2010-03-01 | 2010-03-05 |  |  | Заказчик; Специалист ИТ; Совет Директоров | 32h | 32h |
| 26 | 3.1.3 | Доработать концепцию сайта | milestone | 0d | 2010-04-05 A | 2010-04-05 A | 25 | 100% |  | 2010-03-08 | 2010-03-09 | 2d | 2010-03-08 | 2010-03-09 |  |  | Руководитель проекта |  |  |
| 27 | 3.1.4 | Утвердить концепцию сайта |  | 2d | 2010-04-06 A | 2010-04-07 A | 26 | 100% |  | 2010-03-10 | 2010-03-10 | 1d | 2010-03-10 | 2010-03-10 |  |  | Заказчик | 16h | 16h |
| 28 | 3.1.5 | Концепция сайта утверждена Заказчиком | milestone | 0d | 2010-04-07 A | 2010-04-07 A | 27 | 100% |  | 2010-03-10 | 2010-03-10 | 0d | 2010-03-10 | 2010-03-10 |  |  |  |  |  |

| ID | WBS | Task | Type | Duration | Start | Finish | Predecessors | Complete | Remaining | Baseline start | Baseline finish | Baseline duration | Baseline 1 start | Baseline 1 finish | Total slack | Free slack | Constraint | Resources | Work | Actual work |
| --- | --- | --- | --- | --- | --- | --- | --- | --- | --- | --- | --- | --- | --- | --- | --- | --- | --- | --- | --- | --- |
| 29 | 3.2 | **Разработать дизайн сайта** |  | 57d | 2010-04-29 A | 2010-07-16 A |  | 100% |  | 2010-04-16 | 2010-05-14 | 21d | 2010-04-16 | 2010-05-14 |  |  |  |  | 200h | 200h |
| 30 | 3.2.1 | Разработать дизайн сайта |  | 37d | 2010-04-29 A | 2010-06-18 A | 21, 28, 36 | 100% |  | 2010-04-16 | 2010-04-29 | 10d | 2010-04-16 | 2010-04-29 |  |  |  | Подрядчик ФС [32.4%] | 96h | 96h |
| 31 | 3.2.2 | Согласовать дизайн сайта |  | 1d | 2010-07-06 A | 2010-07-06 A | 30 | 100% |  | 2010-04-30 | 2010-05-06 | 5d | 2010-04-30 | 2010-05-06 |  |  |  | Заказчик; Специалист ИТ | 16h | 16h |
| 32 | 3.2.3 | Доработать дизайн сайта |  | 8d | 2010-07-07 A | 2010-07-16 A | 31 | 100% |  | 2010-05-07 | 2010-05-13 | 5d | 2010-05-07 | 2010-05-13 |  |  |  | Подрядчик ФС | 64h | 64h |
| 33 | 3.2.4 | Утвердить дизайн сайта |  | 3d | 2010-07-14 A | 2010-07-16 A | 32 | 100% |  | 2010-05-14 | 2010-05-14 | 1d | 2010-05-14 | 2010-05-14 |  |  |  | Заказчик | 24h | 24h |
| 34 | 3.2.5 | Дизайн сайта утвержден Заказчиком | milestone | 0d | 2010-07-16 A | 2010-07-16 A | 33 | 100% |  | 2010-05-14 | 2010-05-14 | 0d | 2010-05-14 | 2010-05-14 |  |  |  |  |  |  |
| 35 | 3.3 | **Разработать первичный контент сайта** |  | 55d | 2010-05-03 A | 2010-07-16 A |  | 100% |  | 2010-03-11 | 2010-04-28 | 35d | 2010-03-11 | 2010-04-28 |  |  |  |  | 408h | 408h |
| 36 | 3.3.1 | Разработать первичный контент сайта |  | 39d | 2010-05-03 A | 2010-06-24 A | 28 | 100% |  | 2010-03-11 | 2010-03-24 | 10d | 2010-03-11 | 2010-03-24 |  |  | start no earlier than 2010-04-30 | Заказчик | 312h | 312h |
| 37 | 3.3.2 | Согласовать первичный контент сайта | milestone | 0d | 2010-06-30 A | 2010-06-30 A | 36, 31 | 100% |  | 2010-03-25 | 2010-03-29 | 3d | 2010-03-25 | 2010-03-29 |  |  |  | Заказчик; Руководитель проекта |  |  |
| 38 | 3.3.3 | Доработать первичный контент сайта | milestone | 0d | 2010-06-30 A | 2010-06-30 A | 37 | 100% |  | 2010-03-30 | 2010-04-01 | 3d | 2010-03-30 | 2010-04-01 |  |  |  | Заказчик |  |  |
| 39 | 3.3.4 | Утвердить первичный контент сайта | milestone | 0d | 2010-06-30 A | 2010-06-30 A | 38 | 100% |  | 2010-04-02 | 2010-04-02 | 1d | 2010-04-02 | 2010-04-02 |  |  |  | Руководитель проекта |  |  |
| 40 | 3.3.5 | Отредактировать первичный контент сайта |  | 9d | 2010-07-01 A | 2010-07-13 A | 39 | 100% |  | 2010-04-05 | 2010-04-09 | 5d | 2010-04-05 | 2010-04-09 |  |  |  | Подрядчик Сайт | 72h | 72h |
| 41 | 3.3.6 | Согласование и утверждение отредактированного первичного контента сайта |  | 3d | 2010-07-14 A | 2010-07-16 A | 40 | 100% |  | 2010-04-12 | 2010-04-14 | 3d | 2010-04-12 | 2010-04-14 |  |  |  | Руководитель проекта | 24h | 24h |
| 42 | 3.3.7 | Резерв к вехе "Контент сайта согласован и утвержден" | milestone | 0d | 2010-07-16 A | 2010-07-16 A | 41 | 100% |  | 2010-04-15 | 2010-04-28 | 10d | 2010-04-15 | 2010-04-28 |  |  |  |  |  |  |
| 43 | 3.3.8 | Контент сайта согласован и утвержден | milestone | 0d | 2010-07-16 A | 2010-07-16 A | 42 | 100% |  | 2010-04-28 | 2010-04-28 | 0d | 2010-04-28 | 2010-04-28 |  |  |  |  |  |  |
| 44 | 3.4 | **Программирование и верстка сайта; настройка системы управления контентом** |  | 15d | 2010-07-19 | 2010-08-06 |  |  |  | 2010-05-17 | 2010-06-18 | 25d | 2010-05-17 | 2010-06-18 | 0d |  |  |  | 120h |  |
| 45 | 3.4.1 | Программирование и верстка сайта; настройка системы управления контентом |  | 15d | 2010-07-19 | 2010-08-06 | 34 |  |  | 2010-05-17 | 2010-06-18 | 25d | 2010-05-17 | 2010-06-18 | 0d |  |  | Подрядчик Сайт | 120h |  |
| 46 | 3.5 | **Зарегистрировать доменное имя сайта компании логистического провайдера** |  | 38d | 2010-06-15 A | 2010-08-06 |  | 99% | 0d | 2010-03-11 | 2010-03-23 | 9d | 2010-03-11 | 2010-03-23 | 13d |  |  |  | 240h | 240h |
| 47 | 3.5.1 | Разработать варианты доменного имени сайта |  | 9d | 2010-06-15 A | 2010-06-25 A | 28 | 100% |  | 2010-03-11 | 2010-03-12 | 2d | 2010-03-11 | 2010-03-12 |  |  | start no earlier than 2010-06-14 | Руководитель проекта; Заказчик | 144h | 144h |
| 48 | 3.5.2 | Утвердить доменное имя сайта компании логистического провайдера |  | 7d | 2010-06-28 A | 2010-07-06 A | 47 | 100% |  | 2010-03-15 | 2010-03-15 | 1d | 2010-03-15 | 2010-03-15 |  |  |  | Заказчик | 56h | 56h |
| 49 | 3.5.3 | Принять решение о хостинге |  | 2d | 2010-07-05 A | 2010-07-06 A | 48 | 100% |  | 2010-03-16 | 2010-03-16 | 1d | 2010-03-16 | 2010-03-16 |  |  |  | Руководитель проекта; Специалист ИТ | 32h | 32h |
| 50 | 3.5.4 | Подать документы на регистрацию доменного имени |  | 1d | 2010-07-06 A | 2010-07-06 A | 49 | 100% |  | 2010-03-17 | 2010-03-23 | 5d | 2010-03-17 | 2010-03-23 |  |  |  | Специалист ИТ | 8h | 8h |
| 51 | 3.5.5 | Доменное имя сайта зарегистрировано, хостинг приобретен | milestone | 0d | 2010-08-06 | 2010-08-06 | 50FS+10d |  |  | 2010-03-23 | 2010-03-23 | 0d | 2010-03-23 | 2010-03-23 | 13d | 0d | start no earlier than 2010-08-06 |  |  |  |
| 52 | 3.6 | **Изменить домен электронной почты сотрудников логистического провайдера** |  | 2d | 2010-08-06 | 2010-08-09 |  |  |  | 2010-03-24 | 2010-04-13 | 15d | 2010-03-24 | 2010-04-13 | 13d |  |  |  | 16h |  |
| 53 | 3.6.1 | Изменить домен электронной почты сотрудников логистического провайдера |  | 2d | 2010-08-06 | 2010-08-09 | 50, 51 |  |  | 2010-03-24 | 2010-04-13 | 15d | 2010-03-24 | 2010-04-13 | 13d | 0d |  | Специалист ИТ | 16h |  |
| 54 | 3.6.2 | Домен электронной почты сотрудников логистического провайдера изменен | milestone | 0d | 2010-08-09 | 2010-08-09 | 53 |  |  | 2010-04-13 | 2010-04-13 | 0d | 2010-04-13 | 2010-04-13 | 13d |  |  |  |  |  |

| ID | WBS | Task | Type | Duration | Start | Finish | Predecessors | Complete | Remaining | Baseline start | Baseline finish | Baseline duration | Baseline 1 start | Baseline 1 finish | Total slack | Free slack | Constraint | Resources | Work | Actual work |
| --- | --- | --- | --- | --- | --- | --- | --- | --- | --- | --- | --- | --- | --- | --- | --- | --- | --- | --- | --- | --- |
| 55 | 3.7 | **Разработать и согласовать регламент поддержки контента сайта сотрудниками логистического провайдера** |  | 8d | 2010-06-15 A | 2010-06-24 A |  | 100% |  | 2010-03-11 | 2010-04-13 | 24d | 2010-03-11 | 2010-04-13 |  |  |  |  |  |  |
| 56 | 3.7.1 | Разработать регламент поддержки контента сайта |  | 8d | 2010-06-15 A | 2010-06-24 A | 28 | 100% |  | 2010-03-11 | 2010-03-24 | 10d | 2010-03-11 | 2010-03-24 |  |  | start no earlier than 2010-06-14 | Заказчик |  |  |
| 57 | 3.7.2 | Согласовать регламент поддержки контента сайта | milestone | 0d | 2010-06-24 A | 2010-06-24 A | 56 | 100% |  | 2010-03-25 | 2010-03-31 | 5d | 2010-03-25 | 2010-03-31 |  |  |  | Руководитель проекта; Заказчик |  |  |
| 58 | 3.7.3 | Доработать регламент поддержки контента сайта | milestone | 0d | 2010-06-24 A | 2010-06-24 A | 57 | 100% |  | 2010-04-01 | 2010-04-05 | 3d | 2010-04-01 | 2010-04-05 |  |  |  |  |  |  |
| 59 | 3.7.4 | Утвердить регламент поддержки контента сайта | milestone | 0d | 2010-06-24 A | 2010-06-24 A | 58 | 100% |  | 2010-04-06 | 2010-04-06 | 1d | 2010-04-06 | 2010-04-06 |  |  |  | Заказчик |  |  |
| 60 | 3.7.5 | Резерв к вехе "Регламент поддержки контента сайта утвержден" | milestone | 0d | 2010-06-24 A | 2010-06-24 A | 59 | 100% |  | 2010-04-07 | 2010-04-13 | 5d | 2010-04-07 | 2010-04-13 |  |  |  |  |  |  |
| 61 | 3.7.6 | Регламент поддержки контента сайта утвержден | milestone | 0d | 2010-06-24 A | 2010-06-24 A | 60 | 100% |  | 2010-04-13 | 2010-04-13 | 0d | 2010-04-13 | 2010-04-13 |  |  |  |  |  |  |
| 62 | 3.8 | **Обучить сотрудников работе с сайтом** |  | 0d | 2010-06-24 A | 2010-06-24 A |  | 100% |  | 2010-06-21 | 2010-06-22 | 2d | 2010-06-21 | 2010-06-22 |  |  |  |  |  |  |
| 63 | 3.8.1 | Обучить сотрудников работе с сайтом в соответствии с регламентом поддержки контента сайта | milestone | 0d | 2010-06-24 A | 2010-06-24 A | 61, 45 | 100% |  | 2010-06-21 | 2010-06-22 | 2d | 2010-06-21 | 2010-06-22 |  |  |  |  |  |  |
| 64 | 3.8.2 | Сотрудники обучены | milestone | 0d | 2010-06-24 A | 2010-06-24 A | 63 | 100% |  | 2010-06-22 | 2010-06-22 | 0d | 2010-06-22 | 2010-06-22 |  |  |  |  |  |  |
| 65 | 3.9 | **Провести тестирование и приемку сайта** |  | 13d | 2010-08-09 | 2010-08-25 |  |  |  | 2010-06-21 | 2010-07-07 | 13d | 2010-06-21 | 2010-07-07 | 0d |  |  |  | 168h |  |
| 66 | 3.9.1 | Провести первичную тестовую эксплуатацию сайта |  | 2d | 2010-08-09 | 2010-08-10 | 45 |  |  | 2010-06-21 | 2010-06-22 | 2d | 2010-06-21 | 2010-06-22 | 0d |  |  | Заказчик; Руководитель проекта | 32h |  |
| 67 | 3.9.2 | Провести первичное тестирование безопасности сайта |  | 1d | 2010-08-09 | 2010-08-09 | 45 |  |  | 2010-06-21 | 2010-06-21 | 1d | 2010-06-21 | 2010-06-21 | 1d |  |  | Специалист ИТ | 8h |  |
| 68 | 3.9.3 | Сформировать заключения по результатам тестовой эксплуатации сайта, включая безопасность |  | 1d | 2010-08-11 | 2010-08-11 | 66, 67 |  |  | 2010-06-23 | 2010-06-23 | 1d | 2010-06-23 | 2010-06-23 | 0d |  |  | Заказчик; Специалист ИТ | 16h |  |
| 69 | 3.9.4 | Доработать сайт с учетом заключения |  | 5d | 2010-08-12 | 2010-08-18 | 68 |  |  | 2010-06-24 | 2010-06-30 | 5d | 2010-06-24 | 2010-06-30 | 0d |  |  | Подрядчик Сайт | 40h |  |
| 70 | 3.9.5 | Провести повторную тестовую эксплуатации сайта |  | 2d | 2010-08-19 | 2010-08-20 | 69 |  |  | 2010-07-01 | 2010-07-02 | 2d | 2010-07-01 | 2010-07-02 | 0d |  |  | Заказчик; Руководитель проекта | 32h |  |
| 71 | 3.9.6 | Провести повторное тестирование безопасности сайта |  | 1d | 2010-08-19 | 2010-08-19 | 69 |  |  | 2010-07-01 | 2010-07-01 | 1d | 2010-07-01 | 2010-07-01 | 1d |  |  | Специалист ИТ | 8h |  |
| 72 | 3.9.7 | Провести доработки сайта по результатам повторного тестирования в том числе безопасности |  | 2d | 2010-08-23 | 2010-08-24 | 70, 71 |  |  | 2010-07-05 | 2010-07-06 | 2d | 2010-07-05 | 2010-07-06 | 0d |  |  | Подрядчик Сайт | 16h |  |
| 73 | 3.9.8 | Осуществить приемку сайта |  | 1d | 2010-08-25 | 2010-08-25 | 72 |  |  | 2010-07-07 | 2010-07-07 | 1d | 2010-07-07 | 2010-07-07 | 0d |  |  | Заказчик; Руководитель проекта | 16h |  |
| 74 | 3.9.9 | Сайт принят | milestone | 0d | 2010-08-25 | 2010-08-25 | 73, 43, 51 |  |  | 2010-07-07 | 2010-07-07 | 0d | 2010-07-07 | 2010-07-07 | 0d |  |  |  |  |  |
| 75 | 4 | **Разработать методику оценки качества продвижения брэнда логистического провайдера** |  | 22d | 2010-07-07 A | 2010-08-05 |  | 77% | 5d | 2010-03-11 | 2010-04-06 | 19d | 2010-03-11 | 2010-04-06 | 14d |  |  |  | 192h | 152h |
| 76 | 4.1 | Разработать документ "Методика оценки качества продвижения брэнда ЛП" |  | 2d | 2010-07-07 A | 2010-07-08 A | 28 | 100% |  | 2010-03-11 | 2010-03-24 | 10d | 2010-03-11 | 2010-03-24 |  |  | start no earlier than 2010-06-25 | Руководитель проекта | 16h | 16h |
| 77 | 4.2 | Согласовать документ "Методика оценки качества продвижения брэнда ЛП" |  | 2d | 2010-07-09 A | 2010-07-12 A | 76 | 100% |  | 2010-03-25 | 2010-03-31 | 5d | 2010-03-25 | 2010-03-31 |  |  |  | Заказчик; Подрядчик ФС | 32h | 32h |
| 78 | 4.3 | Доработать документ "Методика оценки качества продвижения брэнда ЛП" |  | 13d | 2010-07-13 A | 2010-07-29 A | 77 | 100% |  | 2010-04-01 | 2010-04-05 | 3d | 2010-04-01 | 2010-04-05 |  |  |  | Руководитель проекта | 104h | 104h |
| 79 | 4.4 | Утвердить документ "Методика оценки качества продвижения брэнда ЛП" |  | 5d | 2010-07-30 | 2010-08-05 | 78 |  |  | 2010-04-06 | 2010-04-06 | 1d | 2010-04-06 | 2010-04-06 | 14d | 0d |  | Заказчик | 40h |  |
| 80 | 4.5 | Методика оценки качества продвижения брэнда ЛП утверждена Заказчиком | milestone | 0d | 2010-08-05 | 2010-08-05 | 79 |  |  | 2010-04-06 | 2010-04-06 | 0d | 2010-04-06 | 2010-04-06 | 14d |  |  |  |  |  |

| ID | WBS | Task | Type | Duration | Start | Finish | Predecessors | Complete | Remaining | Baseline start | Baseline finish | Baseline duration | Baseline 1 start | Baseline 1 finish | Total slack | Free slack | Constraint | Resources | Work | Actual work |
| --- | --- | --- | --- | --- | --- | --- | --- | --- | --- | --- | --- | --- | --- | --- | --- | --- | --- | --- | --- | --- |
| 81 | 5 | **Разработать примерный план маркетинговых коммуникаций логистического провайдера** |  | 18d | 2010-07-07 A | 2010-07-30 |  | 94% | 1d | 2010-04-07 | 2010-05-10 | 24d | 2010-04-07 | 2010-05-10 | 18d |  |  |  | 144h | 136h |
| 82 | 5.1 | Разработать примерный план маркетинговых коммуникаций логистического провайдера |  | 2d | 2010-07-07 A | 2010-07-08 A | 80 | 100% |  | 2010-04-07 | 2010-04-27 | 15d | 2010-04-07 | 2010-04-27 |  |  |  | Руководитель проекта |  |  |
| 83 | 5.2 | Согласовать примерный план маркетинговых коммуникаций логистического провайдера |  | 2d | 2010-07-09 A | 2010-07-12 A | 82 | 100% |  | 2010-04-28 | 2010-05-04 | 5d | 2010-04-28 | 2010-05-04 |  |  |  | Заказчик; Руководитель проекта | 32h | 32h |
| 84 | 5.3 | Доработать примерный план маркетинговых коммуникаций логистического провайдера |  | 13d | 2010-07-13 A | 2010-07-29 A | 83 | 100% |  | 2010-05-05 | 2010-05-07 | 3d | 2010-05-05 | 2010-05-07 |  |  |  | Руководитель проекта | 104h | 104h |
| 85 | 5.4 | Утвердить примерный план маркетинговых коммуникаций логистического провайдера |  | 1d | 2010-07-30 | 2010-07-30 | 84 |  |  | 2010-05-10 | 2010-05-10 | 1d | 2010-05-10 | 2010-05-10 | 18d | 0d |  | Заказчик | 8h |  |
| 86 | 5.5 | Примерный план маркетинговых коммуникаций ЛП утвержден Заказчиком | milestone | 0d | 2010-07-30 | 2010-07-30 | 85 |  |  | 2010-05-10 | 2010-05-10 | 0d | 2010-05-10 | 2010-05-10 | 18d |  |  |  |  |  |
| 87 | 6 | **Изменить название юридического лица логистического провайдера** |  | 57d | 2010-05-17 A | 2010-08-03 A |  | 100% |  | 2010-04-16 | 2010-05-25 | 28d | 2010-04-16 | 2010-05-25 |  |  |  |  | 344h | 344h |
| 88 | 6.1 | Оформить протокол Общего Собрания Участников ОДО "АБВ" |  | 2d | 2010-05-17 A | 2010-05-18 A | 21 | 100% |  | 2010-04-16 | 2010-04-19 | 2d | 2010-04-16 | 2010-04-19 |  |  | start no earlier than 2010-05-15 | Юрист | 16h | 16h |
| 89 | 6.2 | Согласовать новое наименование в управлении юстиции МГИК |  | 1d | 2010-05-19 A | 2010-05-19 A | 88 | 100% |  | 2010-04-20 | 2010-04-20 | 1d | 2010-04-20 | 2010-04-20 |  |  |  | Юрист | 8h | 8h |
| 90 | 6.3 | Изготовить новую печать |  | 3d | 2010-05-20 A | 2010-05-24 A | 89 | 100% |  | 2010-04-21 | 2010-04-23 | 3d | 2010-04-21 | 2010-04-23 |  |  |  | Юрист | 24h | 24h |
| 91 | 6.4 | Подготовить и зарегистрировать изменения в учредительные документы, уничтожить старую печать |  | 2d | 2010-05-25 A | 2010-05-26 A | 90 | 100% |  | 2010-04-26 | 2010-04-27 | 2d | 2010-04-26 | 2010-04-27 |  |  |  | Юрист | 16h | 16h |
| 92 | 6.5 | Уведомить контрагентов |  | 49d | 2010-05-27 A | 2010-08-03 A | 91 | 100% |  | 2010-04-28 | 2010-05-04 | 5d | 2010-04-28 | 2010-05-04 |  |  |  | Юрист | 40h | 40h |
| 93 | 6.6 | Внести исправления в документы Единого гос.регистра недвижимого имущества | milestone | 0d | 2010-06-28 A | 2010-06-28 A | 92 | 100% |  | 2010-05-05 | 2010-05-10 | 4d | 2010-05-05 | 2010-05-10 |  |  |  | Юрист |  |  |
| 94 | 6.7 | Внести изменения в специальные разрешения (лицензии) |  | 1mo | 2010-05-27 A | 2010-06-23 A | 91 | 100% |  | 2010-04-28 | 2010-05-25 | 1mo | 2010-04-28 | 2010-05-25 |  |  |  | Юрист | 160h | 160h |
| 95 | 6.8 | Внести изменения в Положения о филиалах ОДО "АБВ". Уведомить местные исполнительные органы |  | 5d | 2010-05-27 A | 2010-06-02 A | 91 | 100% |  | 2010-04-28 | 2010-05-04 | 5d | 2010-04-28 | 2010-05-04 |  |  |  | Юрист | 40h | 40h |
| 96 | 6.9 | Внести изменения в локальные нормативные акты |  | 5d | 2010-06-28 A | 2010-07-02 A | 95 | 100% |  | 2010-05-05 | 2010-05-11 | 5d | 2010-05-05 | 2010-05-11 |  |  | start no earlier than 2010-06-25 | Юрист | 40h | 40h |
| 97 | 6.10 | Название юридического лица логистического провайдера изменено. Копия новых учредительных документов передана Заказчику проекта | milestone | 0d | 2010-08-03 A | 2010-08-03 A | 89, 90, 91, 92, 93, 94, 95, 96 | 100% |  | 2010-05-25 | 2010-05-25 | 0d | 2010-05-25 | 2010-05-25 |  |  |  |  |  |  |
| 98 | 7 | **Зарегистрировать знак обслуживания** |  | 12d | 2010-06-25 A | 2010-07-13 |  | 99% | 0d | 2010-04-16 | 2010-06-17 | 45d | 2010-04-16 | 2010-06-17 | 32d |  |  |  | 96h | 96h |
| 99 | 7.1 | Подать заявку на регистрацию знака обслуживания | milestone | 0d | 2010-06-25 | 2010-06-25 | 21 |  |  | 2010-04-16 | 2010-04-22 | 5d | 2010-04-16 | 2010-04-22 | 44d |  | start no earlier than 2010-06-25 | Юрист |  |  |
| 100 | 7.2 | Провести предварительную экспертизу знака обслуживания |  | 0.6mo | 2010-06-25 A | 2010-07-13 A | 99 | 100% |  | 2010-04-23 | 2010-06-17 | 2mo | 2010-04-23 | 2010-06-17 |  |  |  | Юрист | 96h | 96h |
| 101 | 7.3 | Заявка принята к рассмотрению | milestone | 0d | 2010-07-13 | 2010-07-13 | 100 |  |  | 2010-06-17 | 2010-06-17 | 0d | 2010-06-17 | 2010-06-17 | 32d |  |  |  |  |  |
| 102 | 8 | **Внести изменения в информационные системы** |  | 3d | 2010-06-28 A | 2010-06-30 A |  | 100% |  | 2010-05-19 | 2010-05-25 | 5d | 2010-05-19 | 2010-05-25 |  |  |  |  | 24h | 24h |
| 103 | 8.1 | Внести изменения в информационные системы |  | 3d | 2010-06-28 A | 2010-06-30 A | 97FF | 100% |  | 2010-05-19 | 2010-05-25 | 5d | 2010-05-19 | 2010-05-25 |  |  | start no earlier than 2010-06-25 | Специалист ИТ | 24h | 24h |
| 104 | 8.2 | Изменения в информационные системы внесены | milestone | 0d | 2010-06-30 A | 2010-06-30 A | 103 | 100% |  | 2010-05-25 | 2010-05-25 | 0d | 2010-05-25 | 2010-05-25 |  |  |  |  |  |  |

| ID | WBS | Task | Type | Duration | Start | Finish | Predecessors | Complete | Baseline start | Baseline finish | Baseline duration | Baseline 1 start | Baseline 1 finish | Total slack | Constraint | Resources | Work |
| --- | --- | --- | --- | --- | --- | --- | --- | --- | --- | --- | --- | --- | --- | --- | --- | --- | --- |
| 105 | 9 | **Подписать акт приема-передачи результатов проекта от руководителя проекта логистическому провайдеру** |  | 1d | 2010-08-26 | 2010-08-26 |  |  | 2010-07-08 | 2010-07-08 | 1d | 2010-07-08 | 2010-07-08 | 0d |  |  | 8h |
| 106 | 9.1 | Подписать у руководителя проекта акт приема-передачи результатов проекта от руководителя проекта логистическому провайдеру |  | 0.5d | 2010-08-26 | 2010-08-26 | 6, 21, 74, 61, 80, 86 |  | 2010-07-08 | 2010-07-08 | 0.5d | 2010-07-08 | 2010-07-08 | 0d |  | Руководитель проекта | 4h |
| 107 | 9.2 | Подписать у генерального директора логистического провайдера акт приема-передачи результатов проекта от руководителя проекта логистическому провайдеру |  | 0.5d | 2010-08-26 | 2010-08-26 | 6, 21, 74, 61, 80, 86, 106 |  | 2010-07-08 | 2010-07-08 | 0.5d | 2010-07-08 | 2010-07-08 | 0d |  | Заказчик | 4h |
| 108 | 9.3 | Акт приема-передачи подписан руководителем проекта и директором ЛП | milestone | 0d | 2010-08-26 | 2010-08-26 | 107 |  | 2010-07-08 | 2010-07-08 | 0d | 2010-07-08 | 2010-07-08 | 0d |  |  |  |
| 109 | 10 | Начало проекта | milestone | 0d | 2010-01-21 A | 2010-01-21 A |  | 100% | 2010-01-21 | 2010-01-21 | 0d | 2010-01-21 | 2010-01-21 |  | start no earlier than 2010-01-21 |  |  |
| 110 | 11 | Проект завершен | milestone | 0d | 2010-08-26 | 2010-08-26 | 108, 64, 104, 54 |  | 2010-07-08 | 2010-07-08 | 0d | 2010-07-08 | 2010-07-08 | 0d |  |  |  |
