# Проект "Ребрендинг"

Schedule from MS Project, 2010-01-04 to 2010-07-13, A marks actual dates.
Microsoft

## Calendars

- Стандартный: Mon-Fri 09:00-13:00, 14:00-18:00; Sat-Sun off.

## Resources

| Resource | Group |
| --- | --- |
| Заказчик | Компания АБВ |
| Руководитель проекта | Управляющая компания |
| Подрядчик ФС | Подрядчик |
| Подрядчик Сайт | Подрядчик |
| Совет Директоров | Управляющая компания |
| Специалист ИТ | ИТ |
| Юрист | Компания АБВ |

## Schedule

| ID | WBS | Task | Type | Duration | Start | Finish | Predecessors | Remaining | Baseline 1 start | Baseline 1 finish | Total slack | Free slack | Resources | Work |
| --- | --- | --- | --- | --- | --- | --- | --- | --- | --- | --- | --- | --- | --- | --- |
| 1 | 1 | **Разработать описание целевой аудитории** |  | 13d | 2010-01-04 | 2010-01-20 |  |  | 2010-01-21 | 2010-02-03 | 0d |  |  | 104h |
| 2 | 1.1 | Разработать описание целевой аудитории |  | 5d | 2010-01-04 | 2010-01-08 | 93 |  | 2010-01-21 | 2010-01-22 | 0d |  | Руководитель проекта | 40h |
| 3 | 1.2 | Согласовать описание целевой аудитории |  | 3d | 2010-01-11 | 2010-01-13 | 2 |  | 2010-01-25 | 2010-01-29 | 0d |  | Заказчик | 24h |
| 4 | 1.3 | Доработать описание целевой аудитории |  | 3d | 2010-01-14 | 2010-01-18 | 3 |  | 2010-02-01 | 2010-02-02 | 0d |  | Руководитель проекта | 24h |
| 5 | 1.4 | Утвердить описания целевой аудитории |  | 2d | 2010-01-19 | 2010-01-20 | 4 |  | 2010-02-03 | 2010-02-03 | 0d |  | Заказчик | 16h |
| 6 | 1.5 | Описание целевой аудитории утверждено Заказчиком | milestone | 0d | 2010-01-20 | 2010-01-20 | 5 |  | 2010-02-03 | 2010-02-03 | 0d |  |  |  |
| 7 | 2 | **Разработать требования к фирменному стилю** |  | 55d | 2010-01-21 | 2010-04-07 |  |  | 2010-02-04 | 2010-04-15 | 0d |  |  | 600h |
| 8 | 2.1 | Разработать требования к фирменному стилю |  | 5d | 2010-01-21 | 2010-01-27 | 6 |  | 2010-02-04 | 2010-02-05 | 0d |  | Руководитель проекта | 40h |
| 9 | 2.2 | Согласовать требования к фирменному стилю |  | 3d | 2010-01-28 | 2010-02-01 | 8 |  | 2010-02-08 | 2010-02-12 | 0d |  | Заказчик; Совет Директоров | 48h |
| 10 | 2.3 | Доработать требования к фирменному стилю по результатам согласования |  | 3d | 2010-02-02 | 2010-02-04 | 9 |  | 2010-02-15 | 2010-02-16 | 0d |  | Руководитель проекта | 24h |
| 11 | 2.4 | Утвердить требования к фирменному стилю |  | 2d | 2010-02-05 | 2010-02-08 | 10 |  | 2010-02-17 | 2010-02-17 | 0d |  | Руководитель проекта; Заказчик | 32h |
| 12 | 2.5 | Резерв к вехе "Требования к фирменному стилю утверждены" |  | 5d | 2010-02-09 | 2010-02-15 | 11 |  | 2010-02-18 | 2010-02-24 | 0d |  |  |  |
| 13 | 2.6 | Требования к фирменному стилю утверждены Заказчиком | milestone | 0d | 2010-02-15 | 2010-02-15 | 12 |  | 2010-02-24 | 2010-02-24 | 0d |  |  |  |
| 14 | 2.7 | **Разработать фирменный стиль** |  | 37d | 2010-02-16 | 2010-04-07 |  |  | 2010-02-25 | 2010-04-15 | 0d |  |  | 456h |
| 15 | 2.7.1 | Совещание с подрядчиком 1 |  | 5d | 2010-02-16 | 2010-02-22 | 13 |  | 2010-02-25 | 2010-03-03 | 0d |  | Руководитель проекта; Заказчик; Подрядчик ФС | 120h |
| 16 | 2.7.2 | Совещание с подрядчиком 2 |  | 5d | 2010-02-23 | 2010-03-01 | 15 |  | 2010-03-04 | 2010-03-10 | 0d |  | Руководитель проекта; Заказчик; Подрядчик ФС | 120h |
| 17 | 2.7.3 | Совещание с подрядчиком 3 |  | 5d | 2010-03-02 | 2010-03-08 | 16 |  | 2010-03-11 | 2010-03-17 | 0d |  | Руководитель проекта; Заказчик; Подрядчик ФС | 120h |
| 18 | 2.7.4 | Доработать фирменный стиль |  | 10d | 2010-03-09 | 2010-03-22 | 17 |  | 2010-03-18 | 2010-03-24 | 0d |  | Подрядчик ФС | 80h |
| 19 | 2.7.5 | Утвердить фирменный стиль |  | 2d | 2010-03-23 | 2010-03-24 | 18 |  | 2010-03-25 | 2010-03-25 | 0d |  | Совет Директоров | 16h |
| 20 | 2.7.6 | Резерв к вехе "Фирменный стиль утвержден" |  | 10d | 2010-03-25 | 2010-04-07 | 19 |  | 2010-03-26 | 2010-04-15 | 0d |  |  |  |
| 21 | 2.7.7 | Фирменный стиль утвержден Советом директоров УК | milestone | 0d | 2010-04-07 | 2010-04-07 | 20 |  | 2010-04-15 | 2010-04-15 | 0d |  |  |  |
| 22 | 3 | **Разработать web-сайт логистического провайдера** |  | 135d | 2010-01-04 A | 2010-07-09 |  | 135d | 2010-02-25 | 2010-07-07 | 2d |  |  | 1216h |
| 23 | 3.1 | **Разработать Требования к сайту ЛП** |  | 20d | 2010-02-16 A | 2010-03-15 |  | 20d | 2010-02-25 | 2010-03-10 | 7d |  |  | 200h |
| 24 | 3.1.1 | Разработать Требования к сайту ЛП |  | 10d | 2010-02-16 | 2010-03-01 | 13 |  | 2010-02-25 | 2010-02-26 | 7d | 0d | Руководитель проекта | 80h |
| 25 | 3.1.2 | Согласовать Требования к сайту ЛП |  | 5d | 2010-03-01 A | 2010-03-08 | 24 | 5d | 2010-03-01 | 2010-03-05 | 7d | 0d | Заказчик; Специалист ИТ; Совет Директоров | 80h |
| 26 | 3.1.3 | Доработать Требования к сайту ЛП |  | 3d | 2010-03-09 | 2010-03-11 | 25 |  | 2010-03-08 | 2010-03-09 | 7d | 0d | Руководитель проекта | 24h |
| 27 | 3.1.4 | Утвердить Требования к сайту ЛП |  | 2d | 2010-03-12 | 2010-03-15 | 26 |  | 2010-03-10 | 2010-03-10 | 7d | 0d | Заказчик | 16h |
| 28 | 3.1.5 | Требования к сайту ЛП утверждены Заказчиком | milestone | 0d | 2010-03-15 | 2010-03-15 | 27 |  | 2010-03-10 | 2010-03-10 | 7d | 0d |  |  |

| ID | WBS | Task | Type | Duration | Start | Finish | Predecessors | Baseline 1 start | Baseline 1 finish | Total slack | Free slack | Resources | Work |
| --- | --- | --- | --- | --- | --- | --- | --- | --- | --- | --- | --- | --- | --- |
| 29 | 3.2 | **Разработать дизайн сайта** |  | 32d | 2010-04-08 | 2010-05-21 |  | 2010-04-16 | 2010-05-14 | 0d |  |  | 264h |
| 30 | 3.2.1 | Разработать дизайн сайта |  | 20d | 2010-04-08 | 2010-05-05 | 21, 28, 36 | 2010-04-16 | 2010-04-29 | 0d |  | Подрядчик ФС | 160h |
| 31 | 3.2.2 | Согласовать дизайн сайта |  | 1d | 2010-05-06 | 2010-05-06 | 30 | 2010-04-30 | 2010-05-06 | 0d |  | Заказчик; Специалист ИТ | 16h |
| 32 | 3.2.3 | Доработать дизайн сайта |  | 8d | 2010-05-07 | 2010-05-18 | 31 | 2010-05-07 | 2010-05-13 | 0d |  | Подрядчик ФС | 64h |
| 33 | 3.2.4 | Утвердить дизайн сайта |  | 3d | 2010-05-19 | 2010-05-21 | 32 | 2010-05-14 | 2010-05-14 | 0d |  | Заказчик | 24h |
| 34 | 3.2.5 | Дизайн сайта утвержден Заказчиком | milestone | 0d | 2010-05-21 | 2010-05-21 | 33 | 2010-05-14 | 2010-05-14 | 0d |  |  |  |
| 35 | 3.3 | **Разработать контент сайта** |  | 66d | 2010-03-16 | 2010-06-15 |  | 2010-03-11 | 2010-04-28 | 7d |  |  | 248h |
| 36 | 3.3.1 | Разработать контент сайта |  | 10d | 2010-03-16 | 2010-03-29 | 28 | 2010-03-11 | 2010-03-24 | 7d |  | Заказчик | 80h |
| 37 | 3.3.2 | Согласовать контент сайта |  | 3d | 2010-05-07 | 2010-05-11 | 36, 31 | 2010-03-25 | 2010-03-29 | 18d | 0d | Заказчик; Руководитель проекта | 48h |
| 38 | 3.3.3 | Доработать контент сайта |  | 3d | 2010-05-12 | 2010-05-14 | 37 | 2010-03-30 | 2010-04-01 | 18d | 0d | Заказчик | 24h |
| 39 | 3.3.4 | Утвердить контент сайта |  | 2d | 2010-05-17 | 2010-05-18 | 38 | 2010-04-02 | 2010-04-02 | 18d | 0d | Руководитель проекта | 16h |
| 40 | 3.3.5 | Отредактировать контент сайта |  | 5d | 2010-05-19 | 2010-05-25 | 39 | 2010-04-05 | 2010-04-09 | 18d | 0d | Подрядчик Сайт | 40h |
| 41 | 3.3.6 | Согласование и утверждение отредактированного контента сайта |  | 5d | 2010-05-26 | 2010-06-01 | 40 | 2010-04-12 | 2010-04-14 | 18d | 0d | Руководитель проекта | 40h |
| 42 | 3.3.7 | Резерв к вехе "Контент сайта согласован и утвержден" |  | 10d | 2010-06-02 | 2010-06-15 | 41 | 2010-04-15 | 2010-04-28 | 18d | 0d |  |  |
| 43 | 3.3.8 | Контент сайта согласован и утвержден | milestone | 0d | 2010-06-15 | 2010-06-15 | 42 | 2010-04-28 | 2010-04-28 | 18d |  |  |  |
| 44 | 3.4 | **Программирование и верстка сайта; настройка системы управления контентом** |  | 20d | 2010-05-24 | 2010-06-18 |  | 2010-05-17 | 2010-06-18 | 0d |  |  | 160h |
| 45 | 3.4.1 | Программирование и верстка сайта; настройка системы управления контентом |  | 20d | 2010-05-24 | 2010-06-18 | 34 | 2010-05-17 | 2010-06-18 | 0d |  | Подрядчик Сайт | 160h |
| 46 | 3.5 | **Провести тестирование и приемку сайта** |  | 15d | 2010-06-21 | 2010-07-09 |  | 2010-06-21 | 2010-07-07 | 0d |  |  | 192h |
| 47 | 3.5.1 | Итерация 1 Провести тестирование сайта пользователям |  | 2d | 2010-06-21 | 2010-06-22 | 45 | 2010-06-21 | 2010-06-22 | 0d |  | Заказчик; Руководитель проекта | 32h |
| 48 | 3.5.2 | Итерация 1 Провести тестирование безопасности сайта |  | 1d | 2010-06-21 | 2010-06-21 | 45 | 2010-06-21 | 2010-06-21 | 1d |  | Специалист ИТ | 8h |
| 49 | 3.5.3 | Итерация 1 Сформировать замечания по результатам тестирования |  | 1d | 2010-06-23 | 2010-06-23 | 47, 48 | 2010-06-23 | 2010-06-23 | 0d |  | Заказчик; Специалист ИТ | 16h |
| 50 | 3.5.4 | Итерация 1 Доработать сайт с учетом замечаний |  | 5d | 2010-06-24 | 2010-06-30 | 49 | 2010-06-24 | 2010-06-30 | 0d |  | Подрядчик Сайт | 40h |
| 51 | 3.5.5 | Итерация 2 Провести тестирование сайта пользователями |  | 2d | 2010-07-01 | 2010-07-02 | 50 | 2010-07-01 | 2010-07-02 | 0d |  | Заказчик; Руководитель проекта | 32h |
| 52 | 3.5.6 | Итерация 2 Провести тестирование безопасности сайта |  | 1d | 2010-07-01 | 2010-07-01 | 50 | 2010-07-01 | 2010-07-01 | 1d |  | Специалист ИТ | 8h |
| 53 | 3.5.7 | Итерация 2 Сформировать замечания по результатам тестирования |  | 1d | 2010-07-05 | 2010-07-05 | 52, 51 |  |  | 0d |  | Заказчик; Специалист ИТ | 16h |
| 54 | 3.5.8 | Итерация 2 Доработать сайт по результатам тестирования |  | 3d | 2010-07-06 | 2010-07-08 | 53 | 2010-07-05 | 2010-07-06 | 0d |  | Подрядчик Сайт | 24h |
| 55 | 3.5.9 | Осуществить приемку сайта |  | 1d | 2010-07-09 | 2010-07-09 | 54 | 2010-07-07 | 2010-07-07 | 0d |  | Заказчик; Руководитель проекта | 16h |
| 56 | 3.5.10 | Сайт принят | milestone | 0d | 2010-07-09 | 2010-07-09 | 55, 43, 62 | 2010-07-07 | 2010-07-07 | 0d |  |  |  |

| ID | WBS | Task | Type | Duration | Start | Finish | Predecessors | Baseline 1 start | Baseline 1 finish | Total slack | Free slack | Resources | Work |
| --- | --- | --- | --- | --- | --- | --- | --- | --- | --- | --- | --- | --- | --- |
| 57 | 3.6 | **Зарегистрировать доменное имя сайта компании логистического провайдера** |  | 15d | 2010-03-16 | 2010-04-05 |  | 2010-03-11 | 2010-03-23 | 69d |  |  | 136h |
| 58 | 3.6.1 | Разработать варианты доменного имени сайта |  | 10d | 2010-03-16 | 2010-03-29 | 28 | 2010-03-11 | 2010-03-12 | 69d | 0d | Руководитель проекта | 80h |
| 59 | 3.6.2 | Утвердить доменное имя сайта компании логистического провайдера |  | 2d | 2010-03-30 | 2010-03-31 | 58 | 2010-03-15 | 2010-03-15 | 69d | 0d | Заказчик | 16h |
| 60 | 3.6.3 | Принять решение о хостинге |  | 2d | 2010-04-01 | 2010-04-02 | 59 | 2010-03-16 | 2010-03-16 | 69d | 0d | Руководитель проекта; Специалист ИТ | 32h |
| 61 | 3.6.4 | Подать документы на регистрацию доменного имени |  | 1d | 2010-04-05 | 2010-04-05 | 60 | 2010-03-17 | 2010-03-23 | 69d | 0d | Специалист ИТ | 8h |
| 62 | 3.6.5 | Доменное имя сайта зарегистрировано, хостинг приобретен | milestone | 0d | 2010-04-05 | 2010-04-05 | 61 | 2010-03-23 | 2010-03-23 | 69d | 0d |  |  |
| 63 | 3.7 | **Изменить домен электронной почты сотрудников логистического провайдера** |  | 2d | 2010-04-06 | 2010-04-07 |  | 2010-03-24 | 2010-04-13 | 69d |  |  | 16h |
| 64 | 3.7.1 | Изменить домен электронной почты сотрудников логистического провайдера |  | 2d | 2010-04-06 | 2010-04-07 | 61, 62 | 2010-03-24 | 2010-04-13 | 69d | 0d | Специалист ИТ | 16h |
| 65 | 3.7.2 | Домен электронной почты сотрудников логистического провайдера изменен | milestone | 0d | 2010-04-07 | 2010-04-07 | 64 | 2010-04-13 | 2010-04-13 | 69d |  |  |  |
| 66 | 3.8 | **Обучить сотрудников работе с сайтом** |  | 2d | 2010-01-04 | 2010-01-05 |  | 2010-06-21 | 2010-06-22 | 135d |  |  |  |
| 67 | 3.8.1 | Обучить сотрудников работе с сайтом в соответствии с регламентом поддержки контента сайта |  | 1d | 2010-01-04 | 2010-01-04 |  | 2010-06-21 | 2010-06-22 | 135d | 0d |  |  |
| 68 | 3.8.2 | Сотрудники обучены |  | 1d | 2010-01-05 | 2010-01-05 | 67 | 2010-06-22 | 2010-06-22 | 135d |  |  |  |
| 69 | 4 | **Разработать план продвижения логистического провайдера** |  | 21d | 2010-01-04 | 2010-02-01 |  | 2010-04-07 | 2010-05-10 | 114d |  |  | 184h |
| 70 | 4.1 | Разработать план продвижения логистического провайдера |  | 5d | 2010-01-04 | 2010-01-08 |  | 2010-04-07 | 2010-04-27 | 114d | 0d | Руководитель проекта | 40h |
| 71 | 4.2 | Согласовать план продвижения логистического провайдера |  | 2d | 2010-01-11 | 2010-01-12 | 70 | 2010-04-28 | 2010-05-04 | 114d | 0d | Заказчик; Руководитель проекта | 32h |
| 72 | 4.3 | Доработать план продвижения логистического провайдера |  | 13d | 2010-01-13 | 2010-01-29 | 71 | 2010-05-05 | 2010-05-07 | 114d | 0d | Руководитель проекта | 104h |
| 73 | 4.4 | Утвердить план продвижения логистического провайдера |  | 1d | 2010-02-01 | 2010-02-01 | 72 | 2010-05-10 | 2010-05-10 | 114d | 0d | Заказчик | 8h |
| 74 | 4.5 | План продвижения логистического провайдера утвержден Заказчиком | milestone | 0d | 2010-02-01 | 2010-02-01 | 73 | 2010-05-10 | 2010-05-10 | 114d |  |  |  |
| 75 | 5 | **Изменить название юридического лица логистического провайдера** |  | 28d | 2010-04-08 | 2010-05-17 |  | 2010-04-16 | 2010-05-25 | 39d |  |  | 360h |
| 76 | 5.1 | Оформить протокол Общего Собрания Участников ОДО "АБВ" |  | 2d | 2010-04-08 | 2010-04-09 | 21 | 2010-04-16 | 2010-04-19 | 39d | 0d | Юрист | 16h |
| 77 | 5.2 | Согласовать новое наименование в управлении юстиции МГИК |  | 1d | 2010-04-12 | 2010-04-12 | 76 | 2010-04-20 | 2010-04-20 | 39d | 0d | Юрист | 8h |
| 78 | 5.3 | Изготовить новую печать |  | 3d | 2010-04-13 | 2010-04-15 | 77 | 2010-04-21 | 2010-04-23 | 39d | 0d | Юрист | 24h |
| 79 | 5.4 | Подготовить и зарегистрировать изменения в учредительные документы, уничтожить старую печать |  | 2d | 2010-04-16 | 2010-04-19 | 78 | 2010-04-26 | 2010-04-27 | 39d | 0d | Юрист | 16h |
| 80 | 5.5 | Уведомить контрагентов |  | 5d | 2010-04-20 | 2010-04-26 | 79 | 2010-04-28 | 2010-05-04 | 52d | 0d | Юрист | 40h |
| 81 | 5.6 | Внести исправления в документы Единого гос.регистра недвижимого имущества |  | 2d | 2010-04-27 | 2010-04-28 | 80 | 2010-05-05 | 2010-05-10 | 52d | 13d | Юрист | 16h |
| 82 | 5.7 | Внести изменения в специальные разрешения (лицензии) |  | 1mo | 2010-04-20 | 2010-05-17 | 79 | 2010-04-28 | 2010-05-25 | 39d | 0d | Юрист | 160h |
| 83 | 5.8 | Внести изменения в Положения о филиалах ОДО "АБВ". Уведомить местные исполнительные органы |  | 5d | 2010-04-20 | 2010-04-26 | 79 | 2010-04-28 | 2010-05-04 | 49d | 0d | Юрист | 40h |
| 84 | 5.9 | Внести изменения в локальные нормативные акты |  | 5d | 2010-04-27 | 2010-05-03 | 83 | 2010-05-05 | 2010-05-11 | 49d | 10d | Юрист | 40h |
| 85 | 5.10 | Название юридического лица логистического провайдера изменено. Копия новых учредительных документов передана Заказчику проекта | milestone | 0d | 2010-05-17 | 2010-05-17 | 77, 78, 79, 80, 81, 82, 83, 84 | 2010-05-25 | 2010-05-25 | 39d |  |  |  |

| ID | WBS | Task | Type | Duration | Start | Finish | Predecessors | Baseline 1 start | Baseline 1 finish | Total slack | Free slack | Resources | Work |
| --- | --- | --- | --- | --- | --- | --- | --- | --- | --- | --- | --- | --- | --- |
| 86 | 6 | **Зарегистрировать знак обслуживания** |  | 14d | 2010-04-08 | 2010-04-27 |  | 2010-04-16 | 2010-06-17 | 53d |  |  | 112h |
| 87 | 6.1 | Подать заявку на регистрацию знака обслуживания |  | 2d | 2010-04-08 | 2010-04-09 | 21 | 2010-04-16 | 2010-04-22 | 53d | 0d | Юрист | 16h |
| 88 | 6.2 | Провести предварительную экспертизу знака обслуживания |  | 0.6mo | 2010-04-12 | 2010-04-27 | 87 | 2010-04-23 | 2010-06-17 | 53d | 0d | Юрист | 96h |
| 89 | 6.3 | Заявка принята к рассмотрению | milestone | 0d | 2010-04-27 | 2010-04-27 | 88 | 2010-06-17 | 2010-06-17 | 53d |  |  |  |
| 90 | 7 | **Подписать акт приема-передачи результатов проекта от руководителя проекта заказчику** |  | 2d | 2010-07-12 | 2010-07-13 |  | 2010-07-08 | 2010-07-08 | 0d |  |  | 32h |
| 91 | 7.1 | Подписать акт приема-передачи результатов проекта от руководителя проекта заказчику |  | 2d | 2010-07-12 | 2010-07-13 | 6, 21, 56, 74, 85, 89 | 2010-07-08 | 2010-07-08 | 0d |  | Руководитель проекта; Заказчик | 32h |
| 92 | 7.2 | Акт приема-передачи подписан руководителем проекта и директором ЛП | milestone | 0d | 2010-07-13 | 2010-07-13 | 91 | 2010-07-08 | 2010-07-08 | 0d |  |  |  |
| 93 | 8 | Начало проекта | milestone | 0d | 2010-01-04 | 2010-01-04 |  | 2010-01-21 | 2010-01-21 | 0d |  |  |  |
| 94 | 9 | Проект завершен | milestone | 0d | 2010-07-13 | 2010-07-13 | 92, 68, 65 | 2010-07-08 | 2010-07-08 | 0d |  |  |  |
